# My New Project

Schedule from MS Project, 2025-06-01 to 2025-11-29, costs in $.

## Calendars

- Estándar: Mon-Fri 07:30-12:00, 13:00-18:00; Sat 07:30-12:00, 13:00-16:25; Sun off.

## Resources

| Resource | Group | Unit | Rate |
| --- | --- | --- | --- |
| Hormigon asfaltico | Material | m3 | 95 |
| MAT Unif Mediano (Base) | Material | m3 | 12.84 |
| Enrocado (hasta D=60cm) | Material | m3 | 13.6 |
| Acero de Refuerzo Fy=4200 kg cm2 | Material | kg | 1.3 |
| Mat Unif Grueso (Sub-base) triturado | Material | m3 | 12.25 |
| Asfalto RC 250 | Material | l | 0.53 |
| Pintura termoplastica (blanca-amarilla) | Material | l | 8.5 |
| Material Cribado | Material | m3 | 4.24 |
| Viga Pretensada f'c=500 kg cm2 - H=120; L= 25m (inc transporte y montaje) | Material | u | 12100 |
| Agua | Material | m3 | 1.24 |
| Geomalla Triaxial de polipropileno | Material | m2 | 2.54 |
| Cascajo mediano | Material | m3 | 2.55 |
| Cascajo grueso | Material | m3 | 2.8 |
| Cemento tipo GU | Material | kg | 0.18 |
| Hormigon Premezclado f'c=280 kg cm2 vaciado directo | Material | m3 | 120.05 |
| Hormigon Premezclado f´c=350 kg cm2 | Material | m3 | 152.55 |
| Mat Ligante (Relleno Mineral) | Material | m3 | 13.25 |
| Geotextil (no tejido 1600) | Material | m2 | 1.16 |
| Perfil tipo W 12 1 2 pies (381) m | Material | u | 88.58 |
| Varios (agua;camisa metal-boca) | Material | glb | 60.73 |
| Ensayos de Integridad; Sensores (deformimetro-acelerometro) con cables Registro | Material | glb | 2280 |
| Mortero de alta resistencia | Material | kg | 0.54 |
| Encofrado (estructuras) | Material | glb | 46.02 |
| Malla Plastica de Seguridad (Color) | Material | m2 | 2.9 |
| Inhibidor de Corrosion - Carboxilato de amina - Hormigon Mezcla | Material | lt | 25.5 |
| Encofrado | Material | u | 50 |
| Junta de dilatacion neopreno modulos (432x54x1830)mm | Material | mts | 403.37 |
| Placa Alum E=2mm | Material | m2 | 45.21 |
| Calidad de Aire Ambiente - Monitoreo de Monóxido de Carbono CO (8horas); Dióxido de Nitrogeno NO2 (1 hora); Dióxido de Azufre SO2 (24 horas); y Ozono O3 (8 horas) | Material | u | 1140 |
| Marcador sin espigo lisa - bidireccional | Material | u | 2.9 |
| Cabina Sanitaria Portatil | Material | mensual | 220 |
| Bentonita | Material | Kg | 0.9 |
| Papel Reflec Grado Diamante (Leyenda) | Material | m2 | 76.23 |
| Fondo para Señal | Material | m2 | 31.37 |
| Poste de HG ( h=180) Guardacamino | Material | u | 46.72 |
| Alambre Recocido #18 | Material | kg | 1.12 |
| Poste de HA 12 mts 500Kg | Material | u | 283.13 |
| Ensayos de laboratorio (Inc Informe Geofísico) | Material | u | 105 |
| Bloque de Anclaje HS F´C= 210 kg cm2 (40x40x40) | Material | u | 14.53 |
| Piedra No 4 | Material | m3 | 11.5 |
| Inhibidor de Corrosion - Carboxilato de amina - Hormigon Mezcla | Material | lt | 25.5 |
| Neopreno tipo STUP (40x40x7cm) | Material | cm3 | 0.03 |
| Monitoreo de calidad de agua | Material | u | 555 |
| Agua | Material | m3 | 1.24 |
| Arena | Material | m3 | 13.25 |
| Microesferas de Vidrio | Material | kg | 1.47 |
| Emulsión Asfaltica | Material | l | 0.48 |
| Luminaria LED solar ALL IN ONE 5700K 80W 18V (FL>11500LM) | Material | u | 880 |
| Carboxilato de Amina - metal | Material | gln | 146 |
| Prueba de Integridad de Pilotes (PIT) | Material | u | 150 |
| Poste Conico 9mts base 30x30cm c 4 pernos de anclaje | Material | u | 792 |
| Aditivo acelerante plastificante | Material | kg | 2.43 |
| Diesel | Material | l | 0.46 |
| Pata Tubo HG (2 X2mm) | Material | mts | 3.7 |
| Pernos de 5 8 x11 4 | Material | u | 1.22 |
| Estructuras (3CA; 3CD; 3CR; 3CP; 3HDT) | Material | u | 128.86 |
| Tirraje Plastico | Material | u | 0.25 |
| Parante Vial de Polietileno enroscable de H=141m D=074m (inc base) | Material | u | 38.01 |
| Material Didactico | Material | glb | 283.67 |
| Perno de Refuerzo 025x050 - 1 4 x 1 2 con tuerca | Material | u | 3 |
| Adhesivo Bituminoso tachas | Material | lb | 1.68 |
| Cono c cinta reflectiva (h=70cm) | Material | u | 15.77 |
| Tanque protector Vial-Polietileno H=102M D=062M INC BASE | Material | u | 78.77 |
| Perno galv de 5 8 x 4 (incluye 2 anillos) | Material | u | 4.36 |
| Pernos anclaje 16mm x 350mm | Material | u | 8.38 |
| Acero estructural ASTM A572 Gr 50 | Material | kg | 1.65 |
| Cono c cinta reflectiva (h=90cm) | Material | u | 27.12 |
| Material Particulado PM25 | Material | u | 180 |
| Material Particulado PM10 | Material | u | 180 |
| Terminal de guardavías (e 25mm) | Material | u | 21.28 |
| Cable de Acero 3 8 (Guia para izado) | Material | u | 2.85 |
| Pintura Primer Gris | Material | gln | 26.59 |
| Pintura Reflectiva (con perlas) | Material | gln | 22.73 |
| Papel Reflec Grado Diamante (Leyenda) | Material | m2 | 76.23 |
| Platina Alum 11 2 x1 8 | Material | mts | 0.8 |
| Acero estructural (A36) | Material | kg | 0.89 |
| Tub Desague EC D=160mm-L=3m | Material | u | 33.86 |
| Pata Tubo HG (2 X2mm) | Material | mts | 3.7 |
| Tubo Cuadrado 2 x2mmx6m (293Kg) | Material | u | 33.99 |
| Wype | Material | lb | 4.12 |
| Bloque de Anclaje de HS (50x50x50) | Material | u | 22.6 |
| Acero Estructural A-588 o A709-50W | Material | kg | 1.25 |
| Tubo HG ( 2 x2 mm ) | Material | u | 45.97 |
| Tira Semidura Encofrado 1 x 4m | Material | u | 1.88 |
| Pintura Primer Gris | Material | gln | 26.59 |
| Acero Estructural A36 (inc Inhibidor de corrosion) | Material | KG | 4.92 |
| Tabla semidura (encofrado de 1 x 4m) | Material | u | 4.95 |
| Pintura reflectiva (sin perlas) | Material | gal | 28.41 |
| Diluyente | Material | gln | 6.12 |
| Señal Luminosa H=03 M A=02 M Inc Bateria 6V | Material | u | 42.56 |
| Base Sop Plancha 122x244x3mm | Material | u | 62.14 |
| Cinta peligro | Material | mts | 0.1 |
| Varilla de Anclaje (Diametro segun pasantes de base de poste) | Material | u | 1.34 |
| Placa Alum E=2mm | Material | m2 | 45.21 |
| Tubo Cuadrado HG (50 x 50 x 2 mm) | Material | mts | 3.7 |
| Toma de muestras con sonometro (muestreo por dia) | Material | u | 40.54 |
| Piedra #3 8 | Material | m3 | 13.25 |
| Bloque de Anclaje HS f'c=210 kg cm2 (25x25x60) | Material | u | 11.02 |
| Lamina Galvanizada 1 16 | Material | m2 | 13.61 |
| Tubo Desague EC 110mm x 3m | Material | u | 14.08 |
| Soldadura 7018 (1 8 ) 29 palillos x kg | Material | kg | 3.2 |
| Aislador de Suspension (de Disco) ANSI 52 - 1;15 KV | Material | u | 7.26 |
| Remaches | Material | u | 0.03 |
| Soldadura 6011; 1 8 (1kg = 380 palillos) | Material | kg | 3.56 |
| Accesorios | Material | glb | 0.67 |
| Tanque metalico c tapa 55gl | Material | u | 16 |
| Cuarton Semiduro Encofrado | Material | u | 3.24 |
| Lona Impresa Full Color (14OZ; respaldo negro; resistencia UV; durabilidad min 2 años) | Material | m2 | 9.01 |
| Tubo PVC Drenaje Corrugado D=160mm | Material | mts | 5.91 |
| Platina 1 1 2 x 1 8 (3mm); 090 kg m; 6m | Material | mts | 1.54 |
| Mat Granu (Explot y Cargada) | Material | m3 | 1.67 |
| Hormigon Simple f'c= 180kg cm2 | Material | m3 | 66.88 |
| Placa Policarbonato 590x210m | Material | u | 130 |
| PLANCHA 122x244x3mm | Material | u | 38 |
| Cable de acero galvanizado; 7 hilos; 951mm (3 8 ) | Material | mts | 2.05 |
| Colgador tipo perla galvanizada D=160mm | Material | u | 3.44 |
| Platina Ref HG 3 4 x1 8¨ | Material | mts | 0.42 |
| Perno Cabeza de coco 1 4 x 3 | Material | u | 0.83 |
| Cable Acero Galvanizado SIEMEMS MARTI; 7 hilos; d=9mm; 3 8 3153KG | Material | mts | 2.05 |
| Pintura Esmalte | Material | gln | 28.45 |
| Hormigon Simple f´c=210kg cm2 | Material | m3 | 95.35 |
| Adhesivo Epoxico (hormigon fresco a endurecido) | Material | kg | 33.95 |
| Brazo p tensor Farol de tubo d=2 ; 150mt de long | Material | u | 32.02 |
| Varilla Anclaje Acero Galvanizada tuerca y arandela (16x1800) mm; (5 8 x71 ) | Material | u | 8.5 |
| Bloque de hormigón para anclaje; con agujero 20 mm; Base d=400mm; h=100mm; Base superior d=150mm | Material | u | 8.05 |
| Anticorrosivo Cromato 5 (CO) | Material | Gln | 19.45 |
| Pintura Esmalte | Material | gln | 28.45 |
| Bloque de Anclaje 40x27x10 cmt | Material | u | 22.6 |
| Guardacabo acero galvanizado 951mm (3 8 ) | Material | u | 6 |
| Varilla de Anclaje d=5 8 ; 180mt de long | Material | u | 12.35 |
| Aislador tipo retenida; Porcelana ANSI 54-2 | Material | u | 3.61 |
| Mordaza; 2 pernos; p cables-acero d=9mm y d=10mm | Material | u | 2.64 |
| Abrazadera Circular de platina 50mmx6 ; 3 pernos | Material | u | 6.52 |
| Guardacabo para cable de acero d=9mm | Material | u | 6 |
| Perno de Refuerzo | Material | u | 0.03 |
| Elementos de Sujecion | Material | glb | 0.23 |
| Clavos de 2 a 3 1 2 | Material | kg | 2.23 |
| Aislador Retenida; clase ANSI 54-3; RED 22GRDY 13;2KV | Material | u | 1.27 |
| Accesorios (pernos; etc) | Material | u | 0.03 |
| Chofer: De volqueta (Estr. Oc. C1) | Mano |  | 6.22 |
| Peón EO E2 | Mano |  | 4.23 |
| Maestro mayor en ejecución de obras civiles EO C1 | Mano |  | 4.75 |
| Engrasador EO D2 | Mano |  | 4.28 |
| Operador de equipo liviano EO D2 | Mano |  | 4.28 |
| Fierrero EO D2 | Mano |  | 4.28 |
| Albañil EO D2 | Mano |  | 4.28 |
| Chofer: De Tanqueros (Estr. Oc. C1) | Mano |  | 6.22 |
| Tecnico Electomecanico de Construccion EO D2 | Mano |  | 4.28 |
| Op. Rodillo autopropulsado EO C2 | Mano |  | 4.52 |
| Op. Excavadora EO C1 | Mano |  | 4.75 |
| Op. Motoniveladora EO C1 | Mano |  | 4.75 |
| Op. Tractor EO C1 | Mano |  | 4.75 |
| Op. Cargadora frontal EO C1 | Mano |  | 4.75 |
| Tecnico obras civiles EO C2 | Mano |  | 4.52 |
| Carpintero EO D2 | Mano |  | 4.28 |
| Op. de acabadora de pavimento asfaltico EO C2 | Mano |  | 4.52 |
| Op. Fresadora de pavimento asfáltico EO C1 | Mano |  | 4.75 |
| Op. de barredora autopropulsada EO C2 | Mano |  | 4.52 |
| Instalador de revestimiento en general EO D2 | Mano |  | 4.28 |
| Op. Compresor EO C2 | Mano |  | 4.52 |
| Chofer De Otros Camiones EO C1 | Mano |  | 6.22 |
| Op. Grua EO C1 | Mano |  | 4.75 |
| Op. Distribuidor de asfalto EO C2 | Mano |  | 4.52 |
| Maestro electrico/liniero/subestaciones EO C1 | Mano |  | 4.75 |
| Electricista EO D2 | Mano |  | 4.28 |
| Chofer EO C1 | Mano |  | 6.22 |
| Soldador en construcción EO C3 | Mano |  | 4.35 |
| Op. Perforadora | Mano |  | 4.75 |
| Plomero EO D2 | Mano |  | 4.28 |
| Pintor EO D2 | Mano |  | 4.28 |
| Tecnico liniero electrico EO D2 | Mano |  | 4.28 |
| Inspector de Obra EO B3 | Mano |  | 4.76 |
| Volqueta (12 ton) | Equipo |  | 30 |
| Excavadora 128hp | Equipo |  | 70 |
| Motoniveladora 135 HP | Equipo |  | 65 |
| Recuperadora de asfalto 460hp | Equipo |  | 193.75 |
| Martillo Neumatico | Equipo |  | 17.5 |
| Tractor de oruga 175 HP | Equipo |  | 58 |
| Cargador Frontal 170hp | Equipo |  | 55 |
| Rodillo P.C Vibratorio 125HP | Equipo |  | 38 |
| Rodillo neumatico 96HP | Equipo |  | 48 |
| Finisher | Equipo |  | 55 |
| Tanquero 8TN | Equipo |  | 30 |
| Tanquero 10TN | Equipo |  | 30 |
| Rodillo Tandem 119 HP | Equipo |  | 45 |
| Compactador Pesado Manual 5HP | Equipo |  | 14.5 |
| Herramienta Menor | Equipo |  | 1 |
| Distribuidor de asfalto 6TN | Equipo |  | 70 |
| Rodillo Vibratorio Liso 142HP | Equipo |  | 42 |
| Tanquero 14 TON | Equipo |  | 39 |
| Grua de servicio | Equipo |  | 65 |
| Grua 45 ton - Barrenadora | Equipo |  | 95 |
| Escoba autopropulsada | Equipo |  | 25 |
| Aplicador Termoplástico | Equipo |  | 30 |
| Cortadora - Dobladora | Equipo |  | 1.75 |
| Soldadora | Equipo |  | 2.2 |
| Equipo de barrenado | Equipo |  | 45 |
| Vibrador de hormigon 1HP | Equipo |  | 4 |
| Carro Canasta Aislado 13mts | Equipo |  | 25 |
| Concretera 1 saco (13HP) | Equipo |  | 4.5 |
| Excavadora 222 HP | Equipo |  | 95 |
| Equipo Mezcla Bituminosa (tacha) | Equipo |  | 8 |
| Rodillo P.C Vibratorio 150HP | Equipo |  | 38 |
| Cargador Frontal 170hp | Equipo |  | 55 |
| Grua 20 Ton | Equipo |  | 45 |
| Maquina Perforadora | Equipo |  | 30 |
| Winche | Equipo |  | 7.5 |
| Escalera telescopica | Equipo |  | 4 |
| Camioneta | Equipo |  | 7.5 |
| Compactador Mediano manual | Equipo |  | 3.5 |
| Grua de Orugas (45 ton) | Equipo |  | 95 |
| Tuberia Tremie | Equipo |  | 2.92 |
| Soldadora | Equipo |  | 2.2 |
| Martillo Diesel | Equipo |  | 40 |
| Equipo de oxicorte | Equipo |  | 1.25 |
| Compresor 2.0HP 8gl (para pintar) | Equipo |  | 8 |
| Esmeril | Equipo |  | 1.25 |
| Elevador Canasta | Equipo |  | 50 |
| Motosierra 7HP | Equipo |  | 1.25 |
| Amoladora | Equipo |  | 1.25 |

## Schedule

| ID | Task | Type | Duration | Start | Finish | Predecessors | Total slack | Free slack | Resources | Work | Cost | Text1 | Text3 | Text4 | Text5 | Text6 | Text7 | Text8 | Text2 | Text9 |
| --- | --- | --- | --- | --- | --- | --- | --- | --- | --- | --- | --- | --- | --- | --- | --- | --- | --- | --- | --- | --- |
| 1 | Inicio | milestone | 0d | 2025-06-01 | 2025-06-01 |  | 0d |  |  |  |  |  |  |  |  |  |  |  |  |  |
| 2 | LETRERO DE OBRA 4.5X3M inc. estructura metalica, lona con impresión color |  | 30d | 2025-06-02 | 2025-07-01 | 1SS | 0d |  | Acero de Refuerzo Fy=4200 kg cm2 [37.31 kg]; Alambre Recocido #18 [1.87 kg]; Acero Estructural A36 (inc Inhibidor de corrosion) [83.41 KG]; Base Sop Plancha 122x244x3mm [0.13 u]; Perno de Refuerzo 025x050 - 1 4 x 1 2 con tuerca [8 u]; Hormigon Simple f´c=210kg cm2 [0.36 m3]; Remaches [75 u]; Pintura Esmalte [0.83 gln]; Lona Impresa Full Color (14OZ; respaldo negro; resistencia UV; durabilidad min 2 años) [13.5 m2]; Soldadura 6011; 1 8 (1kg = 380 palillos) [2.5 kg]; Peón EO E2 [200%]; Instalador de revestimiento en general EO D2; Tecnico Electomecanico de Construccion EO D2; Maestro mayor en ejecución de obras civiles EO C1; Soldadora; Herramienta Menor | 84h | 1,131.23 | 503597 | 1.00 | 12.0003 | 12.00 | 1.50 | 1132.3015 | 1132.3 |  |  |
| 3 | DESBROCE, DESBOSQUE Y LIMPIEZA |  | 30d | 2025-06-02 | 2025-07-01 | 2SS | 0d |  | Op. Tractor EO C1; Engrasador EO D2; Peón EO E2 [200%]; Tractor de oruga 175 HP; Motosierra 7HP [200%]; Herramienta Menor | 77.44h | 879.41 | 503598 | 5.50 | 1.7642 | 9.70 | 1.21 | 160.0026 | 880.01 | Ha |  |
| 4 | REUBICACIÓN DE POSTES / H.A. DE ALUMBRADO no inc. Desvestimiento |  | 30d | 2025-06-02 | 2025-07-01 | 3SS | 0d |  | Bloque de Anclaje de HS (50x50x50) [8 u]; Aislador de Suspension (de Disco) ANSI 52 - 1;15 KV [8 u]; Cable de Acero 3 8 (Guia para izado) [120 u]; Varilla de Anclaje (Diametro segun pasantes de base de poste) [72 u]; Chofer De Otros Camiones EO C1; Maestro electrico/liniero/subestaciones EO C1; Peón EO E2 [200%]; Grua de servicio; Herramienta Menor | 96h | 2,351.16 | 503599 | 8.00 | 2.0034 | 16.03 | 2.00 | 294.1279 | 2353.02 |  |  |
| 5 | FRESADA DE CARPETA ASFÁLTICA |  | 90d | 2025-06-02 | 2025-08-30 | 4SS | 0d |  | Op. Fresadora de pavimento asfáltico EO C1; Engrasador EO D2; Peón EO E2 [600%]; Chofer: De Tanqueros (Estr. Oc. C1); Recuperadora de asfalto 460hp; Tanquero 8TN; Herramienta Menor | 3994.56h | 101,650.96 | 503600 | 67,984.00 | 0.0049 | 332.85 | 41.61 | 1.5014 | 102071.18 | m2 |  |
| 6 | EXCAVACION SIN CLASIFICACION empuje = 60 m con % relleno compactado |  | 90d | 2025-06-02 | 2025-08-30 | 5SS | 0d |  | Op. Tractor EO C1; Op. Motoniveladora EO C1 [15%]; Op. Rodillo autopropulsado EO C2 [30%]; Engrasador EO D2; Chofer: De Tanqueros (Estr. Oc. C1) [30%]; Tractor de oruga 175 HP; Motoniveladora 135 HP [15%]; Rodillo P.C Vibratorio 150HP [30%]; Tanquero 8TN [30%]; Herramienta Menor | 607.64h | 12,973 | 503601 | 9,232.50 | 0.0120 | 110.45 | 13.81 | 1.4045 | 12967.05 | m3 |  |
| 7 | DESALOJO MATERIAL DE EXCAVACION distancia hasta 10 km |  | 90d | 2025-06-02 | 2025-08-30 | 6SS | 0d |  | Peón EO E2; Chofer: De volqueta (Estr. Oc. C1) [1600%]; Op. Cargadora frontal EO C1; Volqueta (12 ton) [1600%]; Cargador Frontal 170hp; Herramienta Menor | 861.12h | 17,746.26 | 503602 | 5,092.50 | 0.0047 | 23.88 | 2.99 | 3.5074 | 17861.43 | m3 |  |
| 8 | MATERIAL DE PRESTAMO IMPORTADO |  | 90d | 2025-06-02 | 2025-08-30 | 7SS | 0d |  | Op. Motoniveladora EO C1; Op. Rodillo autopropulsado EO C2; Chofer: De Tanqueros (Estr. Oc. C1); Engrasador EO D2; Op. Tractor EO C1; Op. Cargadora frontal EO C1; Motoniveladora 135 HP; Herramienta Menor; Tanquero 10TN; Tractor de oruga 175 HP; Rodillo P.C Vibratorio 125HP; Cargador Frontal 170hp | 7340.16h | 194,360.21 | 503603 | 38,931.06 | 0.0157 | 611.66 | 76.46 | 4.9966 | 194522.93 | m3 |  |
| 9 | TRANSPORTE DE MATERIAL DE PRESTAMO IMPORTADO, LONGITUD DE ACARREO DE 65-180 KM |  | 90d | 2025-06-02 | 2025-08-30 | 8SS | 0d |  | Chofer: De volqueta (Estr. Oc. C1); Volqueta (12 ton) | 32806.2h | 683,448.32 | 503604 | 2,530,518.90 | 0.0065 | 16,403.14 | 2,050.39 | 0.2707 | 685011.47 | m3-km |  |
| 10 | MATERIAL DE PRESTAMO LOCAL * |  | 90d | 2025-06-02 | 2025-08-30 | 9SS | 0d |  | Op. Cargadora frontal EO C1; Op. Tractor EO C1 [200%]; Op. Motoniveladora EO C1; Engrasador EO D2 [200%]; Chofer: De volqueta (Estr. Oc. C1) [600%]; Chofer: De Tanqueros (Estr. Oc. C1); Op. Rodillo autopropulsado EO C2; Tractor de oruga 175 HP [200%]; Cargador Frontal 170hp; Herramienta Menor; Motoniveladora 135 HP; Rodillo P.C Vibratorio 125HP; Tanquero 10TN; Volqueta (12 ton) [600%] | 375.84h | 8,993.25 | 503605 | 4,140.00 | 0.0034 | 13.94 | 1.74 | 2.2028 | 9119.59 | m3 |  |
| 11 | MEJORAMIENTO DE LA SUBRASANTE CON SUELO SELECCIONADO |  | 90d | 2025-06-02 | 2025-08-30 | 10SS | 0d |  | Cascajo grueso [11247.3 m3]; Op. Rodillo autopropulsado EO C2; Chofer: De Tanqueros (Estr. Oc. C1); Peón EO E2 [200%]; Engrasador EO D2; Op. Motoniveladora EO C1; Motoniveladora 135 HP; Herramienta Menor; Tanquero 8TN; Rodillo Vibratorio Liso 142HP | 556h | 46,841.13 | 503606 | 9,372.74 | 0.0059 | 55.56 | 6.95 | 4.9947 | 46814.02 | m3 | 10 |
| 12 | TRANSPORTE DE MATERIAL DE MEJORAMIENTO, LONGITUD DE ACARREO DE 45-105 KM |  | 90d | 2025-06-02 | 2025-08-30 | 11SS | 0d |  | Chofer: De volqueta (Estr. Oc. C1); Volqueta (12 ton) | 7313.12h | 152,301.44 | 503607 | 609,228.10 | 0.0060 | 3,656.57 | 457.07 | 0.2499 | 152246.1 | m3-km | 11 |
| 13 | SUB-BASE CLASE 1 |  | 90d | 2025-07-01 | 2025-09-30 | 12SS+30d | 0d |  | Material Cribado [5287.9 m3]; Mat Unif Grueso (Sub-base) triturado [3144.16 m3]; Mat Ligante (Relleno Mineral) [500.21 m3]; Peón EO E2 [500%]; Engrasador EO D2; Op. Motoniveladora EO C1; Op. Rodillo autopropulsado EO C2; Chofer: De Tanqueros (Estr. Oc. C1); Herramienta Menor; Tanquero 8TN; Rodillo Vibratorio Liso 142HP; Motoniveladora 135 HP | 617.76h | 87,493.49 | 503608 | 7,145.81 | 0.0067 | 47.53 | 5.94 | 12.26 | 87607.63 | m3 | 12 |
| 14 | TRANSPORTE DE BASE, SUB-BASE Y H. ASFALTICO LONGITUD DE ACARREO DE 30-110 KM |  | 90d | 2025-07-01 | 2025-09-30 | 13SS | 60d |  | Chofer: De volqueta (Estr. Oc. C1); Volqueta (12 ton) | 7318.56h | 152,466.64 | 503609 | 564,518.99 | 0.0065 | 3,659.28 | 457.41 | 0.2707 | 152815.29 | m3-km | 13 |
| 15 | IMPRIMACION ASFALTICA. |  | 90d | 2025-07-31 | 2025-10-30 | 13SS+30d | 0d |  | Asfalto RC 250 [47628 l]; Diesel [882 l]; Op. de barredora autopropulsada EO C2; Op. Distribuidor de asfalto EO C2; Engrasador EO D2; Peón EO E2 [600%]; Escoba autopropulsada; Herramienta Menor; Distribuidor de asfalto 6TN | 105.6h | 30,861.72 | 503610 | 29,400.00 | 0.0003 | 8.81 | 1.10 | 1.0502 | 30875.88 | m2 | 14 |
| 16 | RIEGO DE LIGA |  | 90d | 2025-07-31 | 2025-10-30 | 15SS | 30d |  | Asfalto RC 250 [17640 l]; Diesel [588 l]; Op. de barredora autopropulsada EO C2; Op. Distribuidor de asfalto EO C2; Engrasador EO D2; Peón EO E2 [300%]; Escoba autopropulsada; Herramienta Menor; Distribuidor de asfalto 6TN | 138.96h | 13,214.59 | 503611 | 29,400.00 | 0.0005 | 15.41 | 1.93 | 0.4465 | 13127.1 | m2 | 15 |
| 17 | CAPA DE RODADURA DE HORM. ASF. MEZCLADO EN PLANTA E=5 cm 2" |  | 90d | 2025-08-30 | 2025-11-29 | 15SS+30d | 0d |  | Hormigon asfaltico [1764 m3]; Op. de acabadora de pavimento asfaltico EO C2; Op. Rodillo autopropulsado EO C2 [200%]; Engrasador EO D2; Peón EO E2 [800%]; Rodillo Tandem 119 HP; Rodillo neumatico 96HP; Herramienta Menor; Finisher | 899.84h | 205,696.68 | 503612 | 29,400.00 | 0.0019 | 56.25 | 7.03 | 6.9969 | 205708.86 | m2 | 16 |
| 18 | TRANSPORTE DE BASE, SUB-BASE Y H. ASFALTICO LONGITUD DE ACARREO DE 30-110 KM |  | 90d | 2025-08-30 | 2025-11-29 | 17SS | 0d |  | Chofer: De volqueta (Estr. Oc. C1); Volqueta (12 ton) | 1484.64h | 30,929.14 | 503609 | 114,513.00 | 0.0065 | 742.29 | 92.79 | 0.2707 | 30998.67 | m3-km | 17 |
| 19 | Tendido y compactación de Base y RAP estabilizado con emulsión asfaltico e=20 cm |  | 60d | 2025-08-30 | 2025-10-30 | 18SS | 30d | 0d | Emulsión Asfaltica [5880 l]; Op. Rodillo autopropulsado EO C2 [200%]; Op. Distribuidor de asfalto EO C2; Op. Motoniveladora EO C1; Engrasador EO D2 [200%]; Peón EO E2 [1000%]; Maestro mayor en ejecución de obras civiles EO C1; Herramienta Menor; Rodillo P.C Vibratorio 125HP; Distribuidor de asfalto 6TN; Motoniveladora 135 HP; Rodillo neumatico 96HP | 2523.84h | 42,329.88 | 503613 | 29,400.00 | 0.0039 | 114.69 | 14.34 | 1.4497 | 42621.18 | m2 | 18 |
| 20 | BASE CLASE 1 |  | 60d | 2025-08-30 | 2025-10-30 | 19SS | 30d | 0d | MAT Unif Mediano (Base) [2940 m3]; Peón EO E2 [500%]; Engrasador EO D2; Op. Motoniveladora EO C1; Op. Rodillo autopropulsado EO C2; Chofer: De Tanqueros (Estr. Oc. C1); Herramienta Menor; Tanquero 8TN; Rodillo Vibratorio Liso 142HP; Motoniveladora 135 HP | 198.64h | 46,558.71 | 503614 | 2,352.00 | 0.0065 | 15.26 | 1.91 | 19.8028 | 46576.19 | m3 | 19 |
| 21 | TRANSPORTE DE BASE, SUB-BASE Y H. ASFALTICO LONGITUD DE ACARREO DE 30-110 KM |  | 60d | 2025-08-30 | 2025-10-30 | 20SS | 30d |  | Chofer: De volqueta (Estr. Oc. C1); Volqueta (12 ton) | 2408.8h | 50,182.39 | 503609 | 185,808.00 | 0.0065 | 1,204.43 | 150.55 | 0.2707 | 50298.23 | m3-km | 20 |
| 22 | SUB-BASE CLASE 1 |  | 90d | 2025-07-31 | 2025-10-30 | 13SS+30d | 0d |  | Material Cribado [10044.9 m3]; Mat Unif Grueso (Sub-base) triturado [5972.65 m3]; Mat Ligante (Relleno Mineral) [950.19 m3]; Peón EO E2 [500%]; Engrasador EO D2; Op. Motoniveladora EO C1; Op. Rodillo autopropulsado EO C2; Chofer: De Tanqueros (Estr. Oc. C1); Herramienta Menor; Tanquero 8TN; Rodillo Vibratorio Liso 142HP; Motoniveladora 135 HP | 1174.16h | 166,212.09 | 503608 | 13,574.21 | 0.0067 | 90.29 | 11.29 | 12.26 | 166419.81 | m3 | 21 |
| 23 | TRANSPORTE DE BASE, SUB-BASE Y H. ASFALTICO LONGITUD DE ACARREO DE 30-110 KM |  | 90d | 2025-07-31 | 2025-10-30 | 22SS | 0d |  | Chofer: De volqueta (Estr. Oc. C1); Volqueta (12 ton) | 13902.4h | 289,626.86 | 503609 | 1,072,362.59 | 0.0065 | 6,951.19 | 868.90 | 0.2707 | 290288.55 | m3-km | 22 |
| 24 | BASE CLASE 1 |  | 90d | 2025-07-31 | 2025-10-30 | 23SS | 0d |  | MAT Unif Mediano (Base) [12077.7 m3]; Peón EO E2 [500%]; Engrasador EO D2; Op. Motoniveladora EO C1; Op. Rodillo autopropulsado EO C2; Chofer: De Tanqueros (Estr. Oc. C1); Herramienta Menor; Tanquero 8TN; Rodillo Vibratorio Liso 142HP; Motoniveladora 135 HP | 814.32h | 191,242.95 | 503614 | 9,662.18 | 0.0065 | 62.68 | 7.83 | 19.8028 | 191338.22 | m3 | 23 |
| 25 | TRANSPORTE DE BASE, SUB-BASE Y H. ASFALTICO LONGITUD DE ACARREO DE 30-110 KM |  | 90d | 2025-07-31 | 2025-10-30 | 24SS | 30d |  | Chofer: De volqueta (Estr. Oc. C1); Volqueta (12 ton) | 9895.84h | 206,158.58 | 503609 | 763,312.22 | 0.0065 | 4,947.89 | 618.49 | 0.2707 | 206628.62 | m3-km | 24 |
| 26 | IMPRIMACION ASFALTICA. |  | 90d | 2025-08-30 | 2025-11-29 | 24SS+30d | 0d |  | Asfalto RC 250 [100849 l]; Diesel [1867.57 l]; Op. de barredora autopropulsada EO C2; Op. Distribuidor de asfalto EO C2; Engrasador EO D2; Peón EO E2 [600%]; Escoba autopropulsada; Herramienta Menor; Distribuidor de asfalto 6TN | 223.68h | 65,348.38 | 503610 | 62,252.40 | 0.0003 | 18.65 | 2.33 | 1.0502 | 65377.47 | m2 | 25 |
| 27 | RIEGO DE LIGA |  | 90d | 2025-08-30 | 2025-11-29 | 26SS | 0d |  | Asfalto RC 250 [37351.4 l]; Diesel [1245.05 l]; Op. de barredora autopropulsada EO C2; Op. Distribuidor de asfalto EO C2; Engrasador EO D2; Peón EO E2 [300%]; Escoba autopropulsada; Herramienta Menor; Distribuidor de asfalto 6TN | 293.76h | 27,974.48 | 503611 | 62,252.40 | 0.0005 | 32.63 | 4.08 | 0.4465 | 27795.7 | m2 | 26 |
| 28 | CAPA DE RODADURA DE HORM. ASF. MEZCLADO EN PLANTA E=12.5 cm 5" |  | 90d | 2025-08-30 | 2025-11-29 | 27SS | 0d |  | Hormigon asfaltico [6533.46 m3]; Op. de acabadora de pavimento asfaltico EO C2; Op. Rodillo autopropulsado EO C2 [200%]; Engrasador EO D2; Peón EO E2 [800%]; Rodillo Tandem 119 HP; Rodillo neumatico 96HP; Herramienta Menor; Finisher | 4381.44h | 777,062.7 | 503615 | 43,556.40 | 0.0063 | 273.86 | 34.23 | 17.8531 | 777616.76 | m2 | 27 |
| 29 | TRANSPORTE DE BASE, SUB-BASE Y H. ASFALTICO LONGITUD DE ACARREO DE 30-110 KM |  | 90d | 2025-08-30 | 2025-11-29 | 28SS | 0d |  | Chofer: De volqueta (Estr. Oc. C1); Volqueta (12 ton) | 5498.56h | 114,550.73 | 503609 | 424,130.45 | 0.0065 | 2,749.27 | 343.66 | 0.2707 | 114812.11 | m3-km | 28 |
| 30 | CAPA DE RODADURA DE HORM. ASF. MEZCLADO EN PLANTA E=5 cm 2" |  | 90d | 2025-08-30 | 2025-11-29 | 29SS | 0d |  | Hormigon asfaltico [1121.76 m3]; Op. de acabadora de pavimento asfaltico EO C2; Op. Rodillo autopropulsado EO C2 [200%]; Engrasador EO D2; Peón EO E2 [800%]; Rodillo Tandem 119 HP; Rodillo neumatico 96HP; Herramienta Menor; Finisher | 572.16h | 130,805.49 | 503612 | 18,696.00 | 0.0019 | 35.77 | 4.47 | 6.9969 | 130814.04 | m2 | 29 |
| 31 | TRANSPORTE DE BASE, SUB-BASE Y H. ASFALTICO LONGITUD DE ACARREO DE 30-110 KM |  | 90d | 2025-08-30 | 2025-11-29 | 30SS | 0d |  | Chofer: De volqueta (Estr. Oc. C1); Volqueta (12 ton) | 944h | 19,666.42 | 503609 | 72,820.92 | 0.0065 | 472.03 | 59.00 | 0.2707 | 19712.62 | m3-km | 30 |
| 32 | LIMPIEZA DE CANALES o DESAZOLVE DE CAUCE excavadora ancho >5m |  | 60d | 2025-07-01 | 2025-08-30 | 1SS+30d | 0d |  | Op. Excavadora EO C1; Engrasador EO D2; Excavadora 128hp; Herramienta Menor | 67.52h | 1,551.61 | 503616 | 1,152.79 | 0.0146 | 16.86 | 2.11 | 1.3346 | 1538.51 | m3 | 31 |
| 33 | REMOCION DE TUBERIA H.A. |  | 60d | 2025-07-01 | 2025-08-30 | 32SS | 0d |  | Peón EO E2 [700%]; Op. Excavadora EO C1; Engrasador EO D2; Maestro mayor en ejecución de obras civiles EO C1; Albañil EO D2 [200%]; Herramienta Menor; Excavadora 222 HP | 305.76h | 3,721.23 | 503617 | 44.20 | 0.4942 | 21.85 | 2.73 | 84.9924 | 3756.66 |  | 32 |
| 34 | DESALOJO DE ESCOMBROS distancia hasta 10 km |  | 60d | 2025-07-01 | 2025-08-30 | 33SS | 0d |  | Peón EO E2; Op. Cargadora frontal EO C1; Chofer: De volqueta (Estr. Oc. C1) [1600%]; Herramienta Menor; Cargador Frontal 170hp; Volqueta (12 ton) [1600%] | 17280h | 309,363.81 | 503618 | 8.33 | 0.0047 | 0.04 | 0.00 | 3.5074 | 29.22 | m3 | 33 |
| 35 | EXCAVACION Y RELLENO PARA ESTRUCTURAS |  | 60d | 2025-07-01 | 2025-08-30 | 34SS | 0d |  | Cascajo mediano [506.88 m3]; Engrasador EO D2; Peón EO E2 [200%]; Op. Excavadora EO C1; Excavadora 128hp; Compactador Pesado Manual 5HP; Herramienta Menor | 81.76h | 2,869.88 | 503619 | 422.40 | 0.0277 | 11.72 | 1.46 | 6.7957 | 2870.5 | m3 | 34 |
| 36 | HORMIGON NO ESTRUCTURAL CLASE "E" f´c=180 kg/cm2 PARA REPLANTILLOS |  | 90d | 2025-07-31 | 2025-10-30 | 35SS+30d | 30d | 0d | Cemento tipo GU [7905.12 kg]; Arena [17.01 m3]; Piedra No 4 [24.13 m3]; Agua [4.83 m3]; Maestro mayor en ejecución de obras civiles EO C1; Albañil EO D2; Peón EO E2 [700%]; Herramienta Menor; Concretera 1 saco (13HP) | 186.56h | 3,084.97 | 503620 | 22.98 | 0.7395 | 16.99 | 2.12 | 134.9999 | 3102.3 | m3 | 35 |
| 37 | HORMIGON ESTRUCTURAL CLASE "B" f´c=240 kg/cm2 INC. INHIBIDOR DE CORROSION Y ENCOFRADO |  | 90d | 2025-07-31 | 2025-10-30 | 36SS | 30d | 0d | Cemento tipo GU [57783 kg]; Arena [73.42 m3]; Piedra No 4 [112.85 m3]; Agua [36.71 m3]; Aditivo acelerante plastificante [295.03 kg]; Inhibidor de Corrosion - Carboxilato de amina - Hormigon Mezcla [81.58 lt]; Encofrado (estructuras) [135.96 glb]; Peón EO E2 [1400%]; Albañil EO D2 [200%]; Maestro mayor en ejecución de obras civiles EO C1; Carpintero EO D2; Herramienta Menor; Vibrador de hormigon 1HP [200%]; Concretera 1 saco (13HP) | 2676.96h | 37,725.41 | 503621 | 135.96 | 0.8948 | 121.66 | 15.21 | 280.0008 | 38068.91 | m3 | 36 |
| 38 | ACERO DE REFUERZO EN BARRAS f´y=4200 kg/cm2 |  | 90d | 2025-07-31 | 2025-10-30 | 37SS | 30d |  | Acero de Refuerzo Fy=4200 kg cm2 [24368.9 kg]; Alambre Recocido #18 [1182.96 kg]; Peón EO E2 [200%]; Fierrero EO D2; Maestro mayor en ejecución de obras civiles EO C1; Herramienta Menor; Cortadora - Dobladora | 6126.72h | 61,706.58 | 503622 | 23,659.12 | 0.0432 | 1,021.13 | 127.64 | 2.6036 | 61598.88 | Kg | 37 |
| 39 | RELLENO COMPACTADO compactador manual |  | 90d | 2025-07-01 | 2025-09-30 | 35SS | 0d |  | Agua [31.25 m3]; Cascajo mediano [150 m3]; Peón EO E2 [200%]; Maestro mayor en ejecución de obras civiles EO C1; Compactador Mediano manual; Herramienta Menor | 318.8h | 1,779.76 | 503623 | 125.00 | 0.5101 | 63.76 | 7.97 | 14.0653 | 1758.16 | m3 | 38 |
| 40 | ENROCADO PARA PROTECCIÓN DE PUENTES Y RIVERAS DE RIOS |  | 90d | 2025-07-01 | 2025-09-30 | 39SS | 0d |  | Enrocado (hasta D=60cm) [119.19 m3]; Peón EO E2 [600%]; Albañil EO D2; Maestro mayor en ejecución de obras civiles EO C1; Op. Excavadora EO C1; Engrasador EO D2; Excavadora 128hp; Herramienta Menor | 76.8h | 2,708.15 | 503624 | 115.72 | 0.0556 | 6.43 | 0.80 | 23.5015 | 2719.59 | m3 | 39 |
| 41 | TRANSPORTE DE MATERIAL ENROCADO-PIEDRA, LONGITUD DE ACARREO DE 75-180 KM |  | 90d | 2025-07-01 | 2025-09-30 | 40SS | 0d |  | Chofer: De volqueta (Estr. Oc. C1); Volqueta (12 ton) | 140.48h | 2,926.22 | 503625 | 9,141.88 | 0.0077 | 70.23 | 8.78 | 0.3207 | 2931.8 | m3-km | 40 |
| 42 | LIMPIEZA DE CANALES o DESAZOLVE DE CAUCE excavadora ancho >5m |  | 90d | 2025-07-01 | 2025-09-30 | 41SS | 0d |  | Op. Excavadora EO C1; Engrasador EO D2; Excavadora 128hp; Herramienta Menor | 76.48h | 1,757.37 | 503616 | 1,305.00 | 0.0146 | 19.09 | 2.39 | 1.3346 | 1741.65 | m3 | 41 |
| 43 | GEOTEXTIL 1600NT |  | 90d | 2025-07-01 | 2025-09-30 | 42SS | 0d |  | Geotextil (no tejido 1600) [69.32 m2]; Peón EO E2 [600%]; Maestro mayor en ejecución de obras civiles EO C1; Herramienta Menor | 26.24h | 210.11 | 503626 | 69.32 | 0.0472 | 3.27 | 0.41 | 3.0512 | 211.51 | m2 | 42 |
| 44 | HORMIGON NO ESTRUCTURAL CLASE "E" f´c=180 kg/cm2 PARA REPLANTILLOS |  | 90d | 2025-07-01 | 2025-09-30 | 43SS | 0d |  | Cemento tipo GU [4272.48 kg]; Arena [9.19 m3]; Piedra No 4 [13.04 m3]; Agua [2.61 m3]; Maestro mayor en ejecución de obras civiles EO C1; Albañil EO D2; Peón EO E2 [700%]; Herramienta Menor; Concretera 1 saco (13HP) | 101.2h | 1,668.82 | 503620 | 12.42 | 0.7395 | 9.18 | 1.15 | 134.9999 | 1676.7 | m3 | 43 |
| 45 | HORMIGON ESTRUCTURAL CLASE "B" f´c=240 kg/cm2 INC. INHIBIDOR DE CORROSION Y ENCOFRADO |  | 90d | 2025-07-01 | 2025-09-30 | 44SS | 0d |  | Cemento tipo GU [55692 kg]; Arena [70.76 m3]; Piedra No 4 [108.76 m3]; Agua [35.38 m3]; Aditivo acelerante plastificante [284.36 kg]; Inhibidor de Corrosion - Carboxilato de amina - Hormigon Mezcla [78.62 lt]; Encofrado (estructuras) [131.04 glb]; Peón EO E2 [1400%]; Albañil EO D2 [200%]; Maestro mayor en ejecución de obras civiles EO C1; Carpintero EO D2; Herramienta Menor; Vibrador de hormigon 1HP [200%]; Concretera 1 saco (13HP) | 2580.16h | 36,360.53 | 503621 | 131.04 | 0.8948 | 117.25 | 14.66 | 280.0008 | 36691.3 | m3 | 44 |
| 46 | ACERO DE REFUERZO EN BARRAS f´y=4200 kg/cm2 |  | 90d | 2025-07-01 | 2025-09-30 | 45SS | 0d |  | Acero de Refuerzo Fy=4200 kg cm2 [12532 kg]; Alambre Recocido #18 [608.35 kg]; Peón EO E2 [200%]; Fierrero EO D2; Maestro mayor en ejecución de obras civiles EO C1; Herramienta Menor; Cortadora - Dobladora | 3150.72h | 31,733.31 | 503622 | 12,167.00 | 0.0432 | 525.13 | 65.64 | 2.6036 | 31678 | Kg | 45 |
| 47 | ACERO ESTRUCTURAL A36 inc. Inhibidor de corrosion |  | 90d | 2025-07-01 | 2025-09-30 | 46SS | 0d |  | Acero estructural (A36) [529.42 kg]; Soldadura 7018 (1 8 ) 29 palillos x kg [15.42 kg]; Accesorios (pernos; etc) [10.28 u]; Carboxilato de Amina - metal [5.14 gln]; Diluyente [5.14 gln]; Wype [10.28 lb]; Maestro mayor en ejecución de obras civiles EO C1; Peón EO E2 [200%]; Fierrero EO D2; Tecnico Electomecanico de Construccion EO D2; Operador de equipo liviano EO D2; Herramienta Menor; Soldadora; Equipo de oxicorte; Winche; Esmeril | 322.08h | 2,869.96 | 503627 | 514.00 | 0.0570 | 29.27 | 3.66 | 5.6025 | 2879.68 | Kg | 46 |
| 48 | POSTE HORMIGON ARMADO DE 12 M x 500KG |  | 30d | 2025-10-30 | 2025-11-29 | 108FS-30d | 0d |  | Poste de HA 12 mts 500Kg [15 u]; Peón EO E2 [200%]; Op. Grua EO C1; Electricista EO D2; Maestro electrico/liniero/subestaciones EO C1; Herramienta Menor; Grua de servicio | 104.72h | 6,402.85 | 503628 | 15.00 | 1.0000 | 15.00 | 1.87 | 427.2043 | 6408.06 |  | 47 |
| 49 | SUMINISTRO Y MONTAJE DE ESTRUCTURAS EN POSTES |  | 30d | 2025-10-30 | 2025-11-29 | 48SS | 0d |  | Estructuras (3CA; 3CD; 3CR; 3CP; 3HDT) [15 u]; Peón EO E2 [400%]; Electricista EO D2; Maestro electrico/liniero/subestaciones EO C1; Chofer De Otros Camiones EO C1; Herramienta Menor; Carro Canasta Aislado 13mts; Escalera telescopica | 268.8h | 4,147.09 | 503629 | 15.00 | 1.7920 | 26.88 | 3.36 | 277.5628 | 4163.44 |  | 48 |
| 50 | TENSOR A TIERRA SIMPLE EN MEDIO VOLTAJE |  | 30d | 2025-10-30 | 2025-11-29 | 49SS | 0d |  | Varilla Anclaje Acero Galvanizada tuerca y arandela (16x1800) mm; (5 8 x71 ) [3 u]; Cable de acero galvanizado; 7 hilos; 951mm (3 8 ) [33 mts]; Bloque de hormigón para anclaje; con agujero 20 mm; Base d=400mm; h=100mm; Base superior d=150mm [3 u]; Guardacabo acero galvanizado 951mm (3 8 ) [3 u]; Aislador tipo retenida; Porcelana ANSI 54-2 [3 u]; Maestro electrico/liniero/subestaciones EO C1 [10%]; Peón EO E2 [200%]; Tecnico liniero electrico EO D2; Herramienta Menor | 14.1h | 224.09 | 503630 | 3.00 | 1.1432 | 3.43 | 0.43 | 74.2587 | 222.78 |  | 49 |
| 51 | Tensor farol simple |  | 30d | 2025-10-30 | 2025-11-29 | 50SS | 0d |  | Abrazadera Circular de platina 50mmx6 ; 3 pernos [1 u]; Brazo p tensor Farol de tubo d=2 ; 150mt de long [1 u]; Mordaza; 2 pernos; p cables-acero d=9mm y d=10mm [3 u]; Guardacabo para cable de acero d=9mm [1 u]; Aislador Retenida; clase ANSI 54-3; RED 22GRDY 13;2KV [1 u]; Cable Acero Galvanizado SIEMEMS MARTI; 7 hilos; d=9mm; 3 8 3153KG [18 mts]; Varilla de Anclaje d=5 8 ; 180mt de long [1 u]; Bloque de Anclaje 40x27x10 cmt [1 u]; Peón EO E2 [200%]; Electricista EO D2; Maestro electrico/liniero/subestaciones EO C1; Herramienta Menor | 13.6h | 202.29 | 503631 | 1.00 | 2.7506 | 2.75 | 0.34 | 202.5075 | 202.51 |  | 50 |
| 52 | Retiro de estructuras de soporte en red aérea de media tensión |  | 30d | 2025-10-30 | 2025-11-29 | 51SS | 0d |  | Peón EO E2 [400%]; Electricista EO D2; Maestro electrico/liniero/subestaciones EO C1; Chofer De Otros Camiones EO C1; Herramienta Menor; Carro Canasta Aislado 13mts; Escalera telescopica | 119.2h | 853.57 | 503632 | 15.00 | 0.7965 | 11.95 | 1.49 | 57.5036 | 862.55 |  | 51 |
| 53 | REUBICACIÓN DE POSTES / H.A. DE ALUMBRADO no inc. Desvestimiento |  | 30d | 2025-10-30 | 2025-11-29 | 52SS | 0d |  | Bloque de Anclaje de HS (50x50x50) [15 u]; Aislador de Suspension (de Disco) ANSI 52 - 1;15 KV [15 u]; Cable de Acero 3 8 (Guia para izado) [225 u]; Varilla de Anclaje (Diametro segun pasantes de base de poste) [135 u]; Chofer De Otros Camiones EO C1; Maestro electrico/liniero/subestaciones EO C1; Peón EO E2 [200%]; Grua de servicio; Herramienta Menor | 180.48h | 4,415.25 | 503599 | 15.00 | 2.0034 | 30.05 | 3.76 | 294.1279 | 4411.92 |  | 52 |
| 54 | REUBICACION DE LINEA 3Φ |  | 30d | 2025-10-30 | 2025-11-29 | 53SS | 0d |  | Peón EO E2 [400%]; Electricista EO D2; Maestro electrico/liniero/subestaciones EO C1; Chofer De Otros Camiones EO C1; Herramienta Menor; Carro Canasta Aislado 13mts; Escalera telescopica | 600.8h | 4,300.22 | 503633 | 1,500.00 | 0.0400 | 60.04 | 7.51 | 2.8878 | 4331.7 |  | 53 |
| 55 | DEMOLICION DE ESTRUCTURAS DE H.A. EXISTENTES |  | 90d | 2025-07-01 | 2025-09-30 | 47SS | 0d |  | Peón EO E2 [400%]; Operador de equipo liviano EO D2; Herramienta Menor; Martillo Neumatico | 18377h | 119,881.1 | 503634 | 800.26 | 3.2806 | 2,625.30 | 328.16 | 150.0022 | 120040.76 | m3 | 54 |
| 56 | DESALOJO DE ESCOMBROS distancia hasta 10 km |  | 90d | 2025-07-01 | 2025-09-30 | 55SS | 0d |  | Peón EO E2; Op. Cargadora frontal EO C1; Chofer: De volqueta (Estr. Oc. C1) [1600%]; Herramienta Menor; Cargador Frontal 170hp; Volqueta (12 ton) [1600%] | 135.36h | 2,789.44 | 503618 | 800.26 | 0.0047 | 3.79 | 0.47 | 3.5074 | 2806.83 | m3 | 55 |
| 57 | EXCAVACION Y RELLENO PARA ESTRUCTURAS |  | 90d | 2025-07-01 | 2025-09-30 | 56SS | 0d |  | Cascajo mediano [559.26 m3]; Engrasador EO D2; Peón EO E2 [200%]; Op. Excavadora EO C1; Excavadora 128hp; Compactador Pesado Manual 5HP; Herramienta Menor | 90.72h | 3,173.97 | 503619 | 466.05 | 0.0277 | 12.93 | 1.62 | 6.7957 | 3167.14 | m3 | 56 |
| 58 | SONDEOS DE EXPLORACION DE SUELOS Inc. analisis e informe |  | 90d | 2025-07-01 | 2025-09-30 | 57SS | 0d |  | Ensayos de laboratorio (Inc Informe Geofísico) [40 u]; Op. Perforadora; Peón EO E2 [400%]; Herramienta Menor; Maquina Perforadora | 186.48h | 6,444.15 | 503635 | 40.00 | 0.6667 | 26.67 | 3.33 | 161.1964 | 6447.86 |  | 57 |
| 59 | PILOTE PREBARRENADO D = 600 mm fc= 350 kg/cm2 INC. INHIBIDOR CORROSION |  | 60d | 2025-07-01 | 2025-08-30 | 58SS | 0d |  | Acero de Refuerzo Fy=4200 kg cm2 [38407.7 kg]; Alambre Recocido #18 [1152 kg]; Inhibidor de Corrosion - Carboxilato de amina - Hormigon Mezcla [134.4 lt]; Varios (agua;camisa metal-boca) [256 glb]; Bentonita [6400 Kg]; Hormigon Premezclado f´c=350 kg cm2 [134.6 m3]; Op. Grua EO C1 [200%]; Engrasador EO D2 [400%]; Peón EO E2 [800%]; Tecnico Electomecanico de Construccion EO D2; Fierrero EO D2 [200%]; Maestro mayor en ejecución de obras civiles EO C1 [10%]; Equipo de barrenado; Grua de servicio; Tuberia Tremie; Herramienta Menor; Grua 45 ton - Barrenadora | 1663.69h | 135,466.85 | 503636 | 256.00 | 0.2942 | 75.32 | 9.41 | 529.9973 | 135679.31 |  | 58 |
| 60 | PRUEBA DE CARGA DINAMICA DE PILOTES PDA |  | 60d | 2025-07-01 | 2025-08-30 | 59SS | 0d |  | Ensayos de Integridad; Sensores (deformimetro-acelerometro) con cables Registro [6 glb]; Op. Grua EO C1; Operador de equipo liviano EO D2; Inspector de Obra EO B3 [50%]; Herramienta Menor; Grua de Orugas (45 ton); Martillo Diesel | 16.28h | 16,234.24 | 503637 | 6.00 | 0.4982 | 2.99 | 0.37 | 2706.2094 | 16237.26 |  | 59 |
| 61 | PRUEBA DE INTEGRIDAD DE PILOTES PIT |  | 60d | 2025-07-01 | 2025-08-30 | 60SS | 0d |  | Prueba de Integridad de Pilotes (PIT) [16 u] |  | 2,760 | 503638 | 16.00 | 0.0000 | 0.00 | 0.00 | 172.5 | 2760 |  | 60 |
| 62 | GEOTEXTIL 1600NT |  | 90d | 2025-07-01 | 2025-09-30 | 61SS | 0d |  | Geotextil (no tejido 1600) [51.7 m2]; Peón EO E2 [600%]; Maestro mayor en ejecución de obras civiles EO C1; Herramienta Menor | 19.2h | 155.26 | 503626 | 51.70 | 0.0472 | 2.44 | 0.30 | 3.0512 | 157.75 | m2 | 61 |
| 63 | PIEDRA TRITURADA SUB-DREN |  | 90d | 2025-07-01 | 2025-09-30 | 62SS | 0d |  | Piedra #3 8 [17.36 m3]; Peón EO E2 [200%]; Maestro mayor en ejecución de obras civiles EO C1; Compactador Mediano manual; Herramienta Menor | 62.4h | 518.02 | 503639 | 16.85 | 0.7412 | 12.49 | 1.56 | 30.501 | 513.94 | m3 | 62 |
| 64 | TRANSPORTE DE MATERIALES PÉTREOS* |  | 90d | 2025-07-01 | 2025-09-30 | 63SS | 0d |  | Chofer: De volqueta (Estr. Oc. C1); Volqueta (12 ton) | 16h | 333.16 | 503640 | 1,331.15 | 0.0060 | 7.99 | 1.00 | 0.2499 | 332.65 | m3-km | 63 |
| 65 | Suministro e instalación de tubería PVC perforada 6" Ø160mm Subdren |  | 90d | 2025-07-01 | 2025-09-30 | 64SS | 0d |  | Tubo PVC Drenaje Corrugado D=160mm [20 mts]; Plomero EO D2; Albañil EO D2; Peón EO E2 [200%]; Herramienta Menor | 13.2h | 190.64 | 503641 | 20.00 | 0.1332 | 2.66 | 0.33 | 9.5341 | 190.68 |  | 64 |
| 66 | TUBERIA PVC Ø110mm PARA DRENAJE |  | 90d | 2025-07-01 | 2025-09-30 | 65SS | 0d |  | Tubo Desague EC 110mm x 3m [9.24 u]; Peón EO E2; Albañil EO D2; Plomero EO D2; Herramienta Menor | 10.56h | 191.35 | 503642 | 26.40 | 0.1002 | 2.65 | 0.33 | 7.2148 | 190.47 |  | 65 |
| 67 | HORMIGON NO ESTRUCTURAL CLASE "E" f´c=180 kg/cm2 PARA REPLANTILLOS |  | 90d | 2025-07-31 | 2025-10-30 | 66SS+30d | 0d |  | Cemento tipo GU [1720 kg]; Arena [3.7 m3]; Piedra No 4 [5.25 m3]; Agua [1.05 m3]; Maestro mayor en ejecución de obras civiles EO C1; Albañil EO D2; Peón EO E2 [700%]; Herramienta Menor; Concretera 1 saco (13HP) | 40.48h | 670.78 | 503620 | 5.00 | 0.7395 | 3.70 | 0.46 | 134.9999 | 675 | m3 | 66 |
| 68 | HORMIGON ESTRUCTURAL PREMEZCLADO CLASE "A" f´c=280 kg/cm2 inc. encofrado, inc. aditivos |  | 90d | 2025-07-31 | 2025-10-30 | 67SS | 0d |  | Aditivo acelerante plastificante [91.33 kg]; Inhibidor de Corrosion - Carboxilato de amina - Hormigon Mezcla [91.33 lt]; Hormigon Premezclado f'c=280 kg cm2 vaciado directo [95.9 m3]; Encofrado [91.33 u]; Peón EO E2 [400%]; Albañil EO D2 [300%]; Maestro mayor en ejecución de obras civiles EO C1; Herramienta Menor; Vibrador de hormigon 1HP [200%] | 304.48h | 22,812.21 | 503643 | 91.33 | 0.3031 | 27.68 | 3.46 | 249.9988 | 22832.39 | m3 | 67 |
| 69 | ACERO DE REFUERZO EN BARRAS f´y=4200 kg/cm2 |  | 90d | 2025-07-31 | 2025-10-30 | 68SS | 0d |  | Acero de Refuerzo Fy=4200 kg cm2 [12603.8 kg]; Alambre Recocido #18 [611.84 kg]; Peón EO E2 [200%]; Fierrero EO D2; Maestro mayor en ejecución de obras civiles EO C1; Herramienta Menor; Cortadora - Dobladora | 3168.96h | 31,915.74 | 503622 | 12,236.70 | 0.0432 | 528.14 | 66.02 | 2.6036 | 31859.47 | Kg | 68 |
| 70 | Viga California T fc=450 kg/cm2 l=25m |  | 60d | 2025-08-30 | 2025-10-30 | 69SS+30d | 0d |  | Viga Pretensada f'c=500 kg cm2 - H=120; L= 25m (inc transporte y montaje) [5 u]; Maestro mayor en ejecución de obras civiles EO C1; Peón EO E2 [600%]; Herramienta Menor | 197.76h | 70,461.81 | 503644 | 5.00 | 4.9426 | 24.71 | 3.09 | 14094.8215 | 70474.11 |  | 69 |

| ID | Task | Duration | Start | Finish | Predecessors | Total slack | Resources | Work | Cost | Text1 | Text2 | Text3 | Text4 | Text5 | Text6 | Text7 | Text8 | Text9 |
| --- | --- | --- | --- | --- | --- | --- | --- | --- | --- | --- | --- | --- | --- | --- | --- | --- | --- | --- |
| 71 | APOYO CON MORTERO DE ALTA RESISTENCIA fc=350 kg/cm2 | 60d | 2025-09-30 | 2025-11-29 | 70SS+30d | 0d | Adhesivo Epoxico (hormigon fresco a endurecido) [0.97 kg]; Mortero de alta resistencia [48.51 kg]; Tabla semidura (encofrado de 1 x 4m) [2.64 u]; Cuarton Semiduro Encofrado [2.05 u]; Tira Semidura Encofrado 1 x 4m [1.16 u]; Clavos de 2 a 3 1 2 [0.78 kg]; Alambre Recocido #18 [0.86 kg]; Maestro mayor en ejecución de obras civiles EO C1; Carpintero EO D2; Albañil EO D2; Peón EO E2; Herramienta Menor; Concretera 1 saco (13HP) | 10.56h | 142.88 | 503645 | m3 | 0.21 | 8.3918 | 1.76 | 0.22 | 679.5917 | 142.71 | 70 |
| 72 | APOYO DE NEOPRENO - TIPO STUP 40x40x7 cm | 60d | 2025-09-30 | 2025-11-29 | 71SS | 0d | Neopreno tipo STUP (40x40x7cm) [112000 cm3]; Peón EO E2 [300%]; Maestro mayor en ejecución de obras civiles EO C1; Herramienta Menor | 25.2h | 3,970.69 | 503646 |  | 10.00 | 0.5008 | 5.01 | 0.63 | 396.9463 | 3969.46 | 71 |
| 73 | HORMIGON ESTRUCTURAL CLASE "A" f´c=280 kg/cm2 INC. INHIBIDOR DE CORROSION Y ENCOFRADO | 60d | 2025-08-30 | 2025-10-30 | 70SS | 0d | Cemento tipo GU [4839.2 kg]; Arena [5.52 m3]; Piedra No 4 [8.28 m3]; Agua [2.58 m3]; Aditivo acelerante plastificante [24.2 kg]; Inhibidor de Corrosion - Carboxilato de amina - Hormigon Mezcla [5.52 lt]; Encofrado (estructuras) [3.04 glb]; Peón EO E2 [1400%]; Albañil EO D2 [200%]; Maestro mayor en ejecución de obras civiles EO C1; Carpintero EO D2; Herramienta Menor; Vibrador de hormigon 1HP [200%]; Concretera 1 saco (13HP) | 193.6h | 2,506.61 | 503647 | m3 | 9.20 | 0.9546 | 8.78 | 1.10 | 274.9951 | 2529.95 | 72 |
| 74 | ACERO DE REFUERZO EN BARRAS f´y=4200 kg/cm2 | 60d | 2025-08-30 | 2025-10-30 | 73SS | 0d | Acero de Refuerzo Fy=4200 kg cm2 [1045.65 kg]; Alambre Recocido #18 [50.76 kg]; Peón EO E2 [200%]; Fierrero EO D2; Maestro mayor en ejecución de obras civiles EO C1; Herramienta Menor; Cortadora - Dobladora | 263.04h | 2,648.27 | 503622 | Kg | 1,015.19 | 0.0432 | 43.82 | 5.48 | 2.6036 | 2643.15 | 73 |
| 75 | HORMIGON ESTRUCTURAL PREMEZCLADO CLASE "A" f´c=280 kg/cm2 inc. encofrado, inc. aditivos | 90d | 2025-08-30 | 2025-11-29 | 74SS | 0d | Aditivo acelerante plastificante [86.1 kg]; Inhibidor de Corrosion - Carboxilato de amina - Hormigon Mezcla [86.1 lt]; Hormigon Premezclado f'c=280 kg cm2 vaciado directo [90.41 m3]; Encofrado [86.1 u]; Peón EO E2 [400%]; Albañil EO D2 [300%]; Maestro mayor en ejecución de obras civiles EO C1; Herramienta Menor; Vibrador de hormigon 1HP [200%] | 286.88h | 21,505.23 | 503643 | m3 | 86.10 | 0.3031 | 26.10 | 3.26 | 249.9988 | 21524.9 | 74 |
| 76 | ACERO DE REFUERZO EN BARRAS f´y=4200 kg/cm2 | 90d | 2025-08-30 | 2025-11-29 | 75SS | 0d | Acero de Refuerzo Fy=4200 kg cm2 [6807.06 kg]; Alambre Recocido #18 [330.44 kg]; Peón EO E2 [200%]; Fierrero EO D2; Maestro mayor en ejecución de obras civiles EO C1; Herramienta Menor; Cortadora - Dobladora | 1711.2h | 17,236.07 | 503622 | Kg | 6,608.80 | 0.0432 | 285.24 | 35.65 | 2.6036 | 17206.67 | 75 |
| 77 | JUNTA DE DILATACION MODULOS DE 432x54x1830MM DESPLAZAMIENTO MEDIO | 60d | 2025-09-30 | 2025-11-29 | 76SS+30d | 0d | Junta de dilatacion neopreno modulos (432x54x1830)mm [20 mts]; Maestro mayor en ejecución de obras civiles EO C1; Peón EO E2 [300%]; Herramienta Menor | 100h | 9,701.25 | 503648 |  | 20.00 | 1.0001 | 20.00 | 2.50 | 484.9365 | 9698.73 | 76 |
| 78 | HORMIGON ESTRUCTURAL CLASE "A" f´c=280 kg/cm2 INC. INHIBIDOR DE CORROSION Y ENCOFRADO | 60d | 2025-09-30 | 2025-11-29 | 77SS | 0d | Cemento tipo GU [16700.5 kg]; Arena [19.05 m3]; Piedra No 4 [28.57 m3]; Agua [8.89 m3]; Aditivo acelerante plastificante [83.5 kg]; Inhibidor de Corrosion - Carboxilato de amina - Hormigon Mezcla [19.05 lt]; Encofrado (estructuras) [10.48 glb]; Peón EO E2 [1400%]; Albañil EO D2 [200%]; Maestro mayor en ejecución de obras civiles EO C1; Carpintero EO D2; Herramienta Menor; Vibrador de hormigon 1HP [200%]; Concretera 1 saco (13HP) | 667.04h | 8,646.04 | 503647 | m3 | 31.75 | 0.9546 | 30.31 | 3.79 | 274.9951 | 8731.09 | 77 |
| 79 | ACERO DE REFUERZO EN BARRAS f´y=4200 kg/cm2 | 60d | 2025-09-30 | 2025-11-29 | 78SS | 0d | Acero de Refuerzo Fy=4200 kg cm2 [1712.93 kg]; Alambre Recocido #18 [83.15 kg]; Peón EO E2 [200%]; Fierrero EO D2; Maestro mayor en ejecución de obras civiles EO C1; Herramienta Menor; Cortadora - Dobladora | 430.56h | 4,337.13 | 503622 | Kg | 1,663.04 | 0.0432 | 71.78 | 8.97 | 2.6036 | 4329.89 | 78 |
| 80 | SUMINISTRO, FABRICACION Y MONTAJE DE ELEMENTOS DE ACERO ESTRUCTURAL ASTM A588 o A709-50W INC. TRANSPORTE | 60d | 2025-09-30 | 2025-11-29 | 79SS | 0d | Soldadura 7018 (1 8 ) 29 palillos x kg [11.67 kg]; Carboxilato de Amina - metal [3.89 gln]; Diluyente [19.45 gln]; Wype [38.91 lb]; Acero Estructural A-588 o A709-50W [400.72 kg]; Maestro mayor en ejecución de obras civiles EO C1 [10%]; Soldador en construcción EO C3 [200%]; Pintor EO D2 [50%]; Peón EO E2 [200%]; Engrasador EO D2; Op. Grua EO C1; Operador de equipo liviano EO D2; Herramienta Menor; Compresor 2.0HP 8gl (para pintar) [50%]; Equipo de oxicorte; Soldadora; Amoladora [50%]; Winche; Grua 20 Ton | 66.37h | 2,125.48 | 503649 | kg | 389.05 | 0.0126 | 4.89 | 0.61 | 5.4768 | 2130.75 | 79 |
| 81 | SUMINISTRO, FABRICACION Y MONTAJE DE ELEMENTOS DE ACERO ESTRUCTURAL ASTM A-572 INC. TRANSPORTE | 60d | 2025-09-30 | 2025-11-29 | 80SS | 0d | Soldadura 7018 (1 8 ) 29 palillos x kg [22.3 kg]; Carboxilato de Amina - metal [7.43 gln]; Diluyente [37.16 gln]; Wype [74.32 lb]; Acero estructural ASTM A572 Gr 50 [765.53 kg]; Maestro mayor en ejecución de obras civiles EO C1 [10%]; Soldador en construcción EO C3 [200%]; Pintor EO D2 [50%]; Peón EO E2 [200%]; Engrasador EO D2; Op. Grua EO C1; Operador de equipo liviano EO D2; Herramienta Menor; Compresor 2.0HP 8gl (para pintar) [50%]; Equipo de oxicorte; Soldadora; Amoladora [50%]; Winche; Grua 20 Ton | 166.46h | 4,730.16 | 503650 | kg | 743.23 | 0.0165 | 12.27 | 1.53 | 6.378 | 4740.32 | 80 |
| 82 | Pernos de anclaje A193 GR B7 d=16mm | 60d | 2025-09-30 | 2025-11-29 | 81SS | 0d | Pernos anclaje 16mm x 350mm [160 u]; Maestro mayor en ejecución de obras civiles EO C1 [10%]; Peón EO E2 [200%]; Herramienta Menor | 79.36h | 1,832.26 | 503651 |  | 160.00 | 0.1599 | 25.59 | 3.20 | 11.3622 | 1817.95 | 81 |
| 83 | TUBERIA PVC Ø110mm PARA DRENAJE | 60d | 2025-09-30 | 2025-11-29 | 82SS | 0d | Tubo Desague EC 110mm x 3m; Peón EO E2; Albañil EO D2; Plomero EO D2; Herramienta Menor | 4h | 22.26 | 503642 |  | 9.00 | 0.1002 | 0.90 | 0.11 | 7.2148 | 64.93 | 82 |
| 84 | Suministro e instalación de tubería PVC Ø160mm para drenaje en puente incluye abrazadera | 60d | 2025-09-30 | 2025-11-29 | 83SS | 0d | Tub Desague EC D=160mm-L=3m [16.5 u]; Colgador tipo perla galvanizada D=160mm [16.5 u]; Plomero EO D2; Albañil EO D2; Peón EO E2; Herramienta Menor | 19.84h | 786.22 | 503652 |  | 50.00 | 0.0998 | 4.99 | 0.62 | 15.6966 | 784.83 | 83 |
| 85 | SUB-BASE CLASE 3 | 60d | 2025-09-30 | 2025-11-29 | 84SS | 0d | Mat Unif Grueso (Sub-base) triturado; Mat Granu (Explot y Cargada) [63.7 m3]; Peón EO E2 [500%]; Engrasador EO D2; Op. Motoniveladora EO C1; Op. Rodillo autopropulsado EO C2; Chofer: De Tanqueros (Estr. Oc. C1); Herramienta Menor; Tanquero 8TN; Rodillo Vibratorio Liso 142HP; Motoniveladora 135 HP | 13h | 365.96 | 503653 | m3 | 72.80 | 0.0074 | 0.54 | 0.07 | 8.4947 | 618.41 | 84 |
| 86 | TRANSPORTE DE BASE, SUB-BASE Y H. ASFALTICO LONGITUD DE ACARREO DE 30-110 KM | 60d | 2025-09-30 | 2025-11-29 | 85SS | 0d | Chofer: De volqueta (Estr. Oc. C1); Volqueta (12 ton) | 74.56h | 1,553.3 | 503609 | m3-km | 5,751.20 | 0.0065 | 37.28 | 4.66 | 0.2707 | 1556.85 | 85 |
| 87 | HORMIGON NO ESTRUCTURAL CLASE "E" f´c=180 kg/cm2 PARA REPLANTILLOS | 60d | 2025-09-30 | 2025-11-29 | 86SS | 0d | Cemento tipo GU [2304.8 kg]; Arena [4.96 m3]; Piedra No 4 [7.04 m3]; Agua [1.41 m3]; Maestro mayor en ejecución de obras civiles EO C1; Albañil EO D2; Peón EO E2 [700%]; Herramienta Menor; Concretera 1 saco (13HP) | 54.56h | 900.12 | 503620 | m3 | 6.70 | 0.7395 | 4.95 | 0.62 | 134.9999 | 904.5 | 86 |
| 88 | HORMIGON ESTRUCTURAL CLASE "A" f´c=280 kg/cm2 INC. INHIBIDOR DE CORROSION Y ENCOFRADO | 60d | 2025-09-30 | 2025-11-29 | 87SS | 0d | Cemento tipo GU [7574.4 kg]; Arena [8.64 m3]; Piedra No 4 [12.96 m3]; Agua [4.03 m3]; Aditivo acelerante plastificante [37.87 kg]; Inhibidor de Corrosion - Carboxilato de amina - Hormigon Mezcla [8.64 lt]; Encofrado (estructuras) [4.75 glb]; Peón EO E2 [1400%]; Albañil EO D2 [200%]; Maestro mayor en ejecución de obras civiles EO C1; Carpintero EO D2; Herramienta Menor; Vibrador de hormigon 1HP [200%]; Concretera 1 saco (13HP) | 302.72h | 3,922.13 | 503647 | m3 | 14.40 | 0.9546 | 13.75 | 1.72 | 274.9951 | 3959.93 | 87 |
| 89 | ACERO DE REFUERZO EN BARRAS f´y=4200 kg/cm2 | 60d | 2025-09-30 | 2025-11-29 | 88SS | 0d | Acero de Refuerzo Fy=4200 kg cm2 [1977.6 kg]; Alambre Recocido #18 [96 kg]; Peón EO E2 [200%]; Fierrero EO D2; Maestro mayor en ejecución de obras civiles EO C1; Herramienta Menor; Cortadora - Dobladora | 497.28h | 5,007.92 | 503622 | Kg | 1,920.00 | 0.0432 | 82.87 | 10.36 | 2.6036 | 4998.91 | 88 |
| 90 | RIEGO DE LIGA | 60d | 2025-09-30 | 2025-11-29 | 89SS | 0d | Asfalto RC 250; Diesel [4 l]; Op. de barredora autopropulsada EO C2; Op. Distribuidor de asfalto EO C2; Engrasador EO D2; Peón EO E2 [300%]; Escoba autopropulsada; Herramienta Menor; Distribuidor de asfalto 6TN | 9h | 135.49 | 503611 | m2 | 200.00 | 0.0005 | 0.10 | 0.01 | 0.4465 | 89.3 | 89 |
| 91 | CAPA DE RODADURA DE HORM. ASF. MEZCLADO EN PLANTA E=5 cm 2" | 60d | 2025-09-30 | 2025-11-29 | 90SS | 0d | Hormigon asfaltico; Op. de acabadora de pavimento asfaltico EO C2; Op. Rodillo autopropulsado EO C2 [200%]; Engrasador EO D2; Peón EO E2 [800%]; Rodillo Tandem 119 HP; Rodillo neumatico 96HP; Herramienta Menor; Finisher | 16h | 383.2 | 503612 | m2 | 200.00 | 0.0019 | 0.38 | 0.05 | 6.9969 | 1399.38 | 90 |
| 92 | TRANSPORTE DE BASE, SUB-BASE Y H. ASFALTICO LONGITUD DE ACARREO DE 30-110 KM | 60d | 2025-09-30 | 2025-11-29 | 91SS | 0d | Chofer: De volqueta (Estr. Oc. C1); Volqueta (12 ton) | 10.08h | 210.05 | 503609 | m3-km | 779.00 | 0.0065 | 5.05 | 0.63 | 0.2707 | 210.88 | 91 |
| 93 | LUMINARIA LED SOLAR ALL IN ONE 5700K 80W/18V FL >11500LM | 60d | 2025-09-30 | 2025-11-29 | 92SS | 0d | Luminaria LED solar ALL IN ONE 5700K 80W 18V (FL>11500LM); Peón EO E2; Electricista EO D2; Maestro electrico/liniero/subestaciones EO C1; Op. Grua EO C1; Herramienta Menor; Elevador Canasta | 6h | 473.28 | 503654 |  | 3.00 | 0.2667 | 0.80 | 0.10 | 1033.1352 | 3099.41 | 92 |
| 94 | POSTE CONICO 9MTS BASE 30X30CM C/4 PERNOS DE ANCLAJE | 60d | 2025-09-30 | 2025-11-29 | 93SS | 0d | Poste Conico 9mts base 30x30cm c 4 pernos de anclaje [3 u]; Peón EO E2; Electricista EO D2; Maestro electrico/liniero/subestaciones EO C1 [25%]; Op. Grua EO C1; Herramienta Menor; Grua 20 Ton | 7.98h | 2,837.82 | 503655 |  | 3.00 | 0.5002 | 1.50 | 0.19 | 945.4116 | 2836.23 | 93 |
| 95 | EXCAVACION Y DESALOJO excavadora, volqueta | 60d | 2025-09-30 | 2025-11-29 | 94SS | 0d | Op. Excavadora EO C1; Chofer: De volqueta (Estr. Oc. C1); Peón EO E2; Excavadora 128hp; Volqueta (12 ton); Herramienta Menor | 3000.48h | 66,808.26 | 503656 | m3 | 18,524.20 | 0.0270 | 500.08 | 62.51 | 3.6004 | 66694.53 | 94 |
| 96 | RELLENO COMPACTADO CON COMP. MANUAL material del sitio | 60d | 2025-09-30 | 2025-11-29 | 95SS | 0d | Agua [2343.75 m3]; Cascajo mediano [11250 m3]; Peón EO E2 [300%]; Maestro mayor en ejecución de obras civiles EO C1; Herramienta Menor; Compactador Pesado Manual 5HP | 6148.32h | 75,129.9 | 503657 | m3 | 9,375.00 | 0.1093 | 1,024.74 | 128.09 | 7.9997 | 74997.19 | 95 |
| 97 | GEOMALLA TRIAXIAL | 60d | 2025-09-30 | 2025-11-29 | 96SS | 0d | Geomalla Triaxial de polipropileno [15687.8 m2]; Peón EO E2 [500%]; Albañil EO D2; Herramienta Menor | 1751.12h | 53,435.22 | 503658 | m2 | 15,687.84 | 0.0159 | 250.18 | 31.27 | 3.4093 | 53484.55 | 96 |
| 98 | GEOTEXTIL 1600NT | 60d | 2025-09-30 | 2025-11-29 | 97SS | 0d | Geotextil (no tejido 1600) [15687.8 m2]; Peón EO E2 [600%]; Maestro mayor en ejecución de obras civiles EO C1; Herramienta Menor | 5919.36h | 47,475.36 | 503626 | m2 | 15,687.84 | 0.0472 | 739.94 | 92.49 | 3.0512 | 47866.74 | 97 |
| 99 | Recubrimiento con mortero de alta resistencia | 60d | 2025-09-30 | 2025-11-29 | 98SS | 0d | Agua [8.26 m3]; Tira Semidura Encofrado 1 x 4m [206.5 u]; Mortero de alta resistencia [24780 kg]; Maestro mayor en ejecución de obras civiles EO C1; Peón EO E2 [200%]; Albañil EO D2; Herramienta Menor; Concretera 1 saco (13HP) | 1095.84h | 20,672.14 | 503659 | m2 | 826.00 | 0.2212 | 182.68 | 22.83 | 25.001 | 20650.83 | 98 |
| 100 | ENROCADO PARA PROTECCIÓN DE PUENTES Y RIVERAS DE RIOS | 60d | 2025-09-30 | 2025-11-29 | 99SS | 0d | Enrocado (hasta D=60cm) [12034.9 m3]; Peón EO E2 [600%]; Albañil EO D2; Maestro mayor en ejecución de obras civiles EO C1; Op. Excavadora EO C1; Engrasador EO D2; Excavadora 128hp; Herramienta Menor | 7794.24h | 273,823.5 | 503624 | m3 | 11,684.40 | 0.0556 | 649.53 | 81.19 | 23.5015 | 274600.93 | 99 |
| 101 | TRANSPORTE DE MATERIAL ENROCADO-PIEDRA, LONGITUD DE ACARREO DE 75-180 KM | 60d | 2025-09-30 | 2025-11-29 | 100SS | 0d | Chofer: De volqueta (Estr. Oc. C1); Volqueta (12 ton) | 14183h | 295,439.08 | 503625 | m3-km | 923,067.60 | 0.0077 | 7,091.49 | 886.44 | 0.3207 | 296027.78 | 100 |
| 102 | RELLENO COMPACTADO compactador manual | 60d | 2025-09-30 | 2025-11-29 | 101SS | 0d | Agua [3.07 m3]; Cascajo mediano [14.74 m3]; Peón EO E2 [200%]; Maestro mayor en ejecución de obras civiles EO C1; Compactador Mediano manual; Herramienta Menor | 31.2h | 174.42 | 503623 | m3 | 12.28 | 0.5101 | 6.26 | 0.78 | 14.0653 | 172.72 | 101 |
| 103 | HORMIGON NO ESTRUCTURAL CLASE "E" f´c=180 kg/cm2 PARA REPLANTILLOS | 60d | 2025-09-30 | 2025-11-29 | 102SS | 0d | Cemento tipo GU [533.2 kg]; Arena [1.15 m3]; Piedra No 4 [1.63 m3]; Agua [0.33 m3]; Maestro mayor en ejecución de obras civiles EO C1; Albañil EO D2; Peón EO E2 [700%]; Herramienta Menor; Concretera 1 saco (13HP) | 12.32h | 207.02 | 503620 | m3 | 1.55 | 0.7395 | 1.15 | 0.14 | 134.9999 | 209.25 | 102 |
| 104 | HORMIGON ESTRUCTURAL CLASE "A" f´c=280 kg/cm2 INC. INHIBIDOR DE CORROSION Y ENCOFRADO | 60d | 2025-09-30 | 2025-11-29 | 103SS | 0d | Cemento tipo GU; Arena [0.59 m3]; Piedra No 4 [0.88 m3]; Agua [0.27 m3]; Aditivo acelerante plastificante [2.58 kg]; Inhibidor de Corrosion - Carboxilato de amina - Hormigon Mezcla [0.59 lt]; Encofrado (estructuras) [0.32 glb]; Peón EO E2 [1400%]; Albañil EO D2 [200%]; Maestro mayor en ejecución de obras civiles EO C1; Carpintero EO D2; Herramienta Menor; Vibrador de hormigon 1HP [200%]; Concretera 1 saco (13HP) | 22h | 179.88 | 503647 | m3 | 0.98 | 0.9546 | 0.94 | 0.12 | 274.9951 | 269.5 | 103 |
| 105 | ACERO DE REFUERZO EN BARRAS f´y=4200 kg/cm2 | 60d | 2025-09-30 | 2025-11-29 | 104SS | 0d | Acero de Refuerzo Fy=4200 kg cm2 [42.66 kg]; Alambre Recocido #18 [2.07 kg]; Peón EO E2 [200%]; Fierrero EO D2; Maestro mayor en ejecución de obras civiles EO C1; Herramienta Menor; Cortadora - Dobladora | 10.56h | 107.47 | 503622 | Kg | 41.42 | 0.0432 | 1.79 | 0.22 | 2.6036 | 107.84 | 104 |
| 106 | CUBIERTA DE POLICARBONATO SIN ESTRUCTURA | 60d | 2025-09-30 | 2025-11-29 | 105SS | 0d | Placa Policarbonato 590x210m [0.76 u]; Elementos de Sujecion [8.4 glb]; Peón EO E2 [200%]; Maestro mayor en ejecución de obras civiles EO C1 [10%]; Carpintero EO D2; Herramienta Menor | 20.99h | 198.72 | 503660 | m2 | 8.40 | 0.6118 | 5.14 | 0.64 | 23.482 | 197.25 | 105 |
| 107 | ACERO ESTRUCTURAL A36 inc. Inhibidor de corrosion | 60d | 2025-09-30 | 2025-11-29 | 106SS | 0d | Acero estructural (A36) [158.91 kg]; Soldadura 7018 (1 8 ) 29 palillos x kg [4.63 kg]; Accesorios (pernos; etc) [3.09 u]; Carboxilato de Amina - metal [1.54 gln]; Diluyente [1.54 gln]; Wype [3.09 lb]; Maestro mayor en ejecución de obras civiles EO C1; Peón EO E2 [200%]; Fierrero EO D2; Tecnico Electomecanico de Construccion EO D2; Operador de equipo liviano EO D2; Herramienta Menor; Soldadora; Equipo de oxicorte; Winche; Esmeril | 96.8h | 861.88 | 503627 | Kg | 154.28 | 0.0570 | 8.79 | 1.10 | 5.6025 | 864.35 | 106 |
| 108 | SEÑALIZACION HORIZONTAL CONTINUA CON PINTURA TERMOPLASTICA E=2,3 MM EN SECO VIA 15 CM AMARILLA O BLANCA/microesferas | 60d | 2025-09-30 | 2025-11-29 | 107SS | 0d | Microesferas de Vidrio [708.34 kg]; Pintura termoplastica (blanca-amarilla) [4250.03 l]; Peón EO E2 [200%]; Maestro mayor en ejecución de obras civiles EO C1; Op. de barredora autopropulsada EO C2; Op. Compresor EO C2; Herramienta Menor; Escoba autopropulsada; Aplicador Termoplástico | 921.6h | 53,115.55 | 503661 |  | 11,805.64 | 0.0098 | 115.23 | 14.40 | 4.5036 | 53167.88 | 107 |
| 109 | SEÑALIZACION HORIZONTAL SEGMENTADA CON PINTURA TERMOPLASTICA E=2,3 MM EN SECO VIA 15 CM AMARILLA O BLANCA/microesferas | 60d | 2025-09-30 | 2025-11-29 | 108SS | 0d | Microesferas de Vidrio [476.02 kg]; Pintura termoplastica (blanca-amarilla) [1696.72 l]; Peón EO E2 [200%]; Maestro mayor en ejecución de obras civiles EO C1; Op. de barredora autopropulsada EO C2; Op. Compresor EO C2; Herramienta Menor; Escoba autopropulsada; Aplicador Termoplástico | 252.16h | 20,226.08 | 503662 |  | 7,855.18 | 0.0040 | 31.50 | 3.94 | 2.5744 | 20222.38 | 108 |
| 110 | MARCAS DE PAVIMENTO C/PINTURA TERMOPLÁSTICA E=2.3MM SECO "PASOS CEBRA, FLECHAS, LEYENDAS" | 60d | 2025-09-30 | 2025-11-29 | 109SS | 0d | Microesferas de Vidrio [793.02 kg]; Pintura termoplastica (blanca-amarilla) [2627.49 l]; Op. Compresor EO C2; Op. de barredora autopropulsada EO C2; Maestro mayor en ejecución de obras civiles EO C1; Albañil EO D2 [400%]; Escoba autopropulsada; Herramienta Menor; Aplicador Termoplástico | 573.6h | 32,761.52 | 503663 | m2 | 955.45 | 0.0600 | 57.37 | 7.17 | 34.3188 | 32789.9 | 109 |
| 111 | MARCADORES DE PAVIMENTO RETROREFLEJANTES TACHAS bidireccionales | 60d | 2025-09-30 | 2025-11-29 | 110SS | 0d | Marcador sin espigo lisa - bidireccional [2293 u]; Adhesivo Bituminoso tachas [871.34 lb]; Operador de equipo liviano EO D2; Instalador de revestimiento en general EO D2; Maestro mayor en ejecución de obras civiles EO C1 [25%]; Peón EO E2; Herramienta Menor; Equipo Mezcla Bituminosa (tacha) | 1207.08h | 15,395.8 | 503664 |  | 2,293.00 | 0.1003 | 229.90 | 28.74 | 6.6848 | 15328.25 | 110 |
| 112 | Señales al lado de la carretera 750x900 750x900 | 60d | 2025-09-30 | 2025-11-29 | 111SS | 0d | Placa Alum E=2mm [64.8 m2]; Platina Alum 11 2 x1 8 [316.8 mts]; PLANCHA 122x244x3mm [2.4 u]; Perno de Refuerzo 025x050 - 1 4 x 1 2 con tuerca [96 u]; Remaches [2064 u]; Pintura Primer Gris [16.32 gln]; Fondo para Señal [64.8 m2]; Papel Reflec Grado Diamante (Leyenda) [25.92 m2]; Pata Tubo HG (2 X2mm) [144 mts]; Accesorios [48 glb]; Bloque de Anclaje HS F´C= 210 kg cm2 (40x40x40) [48 u]; Soldadura 6011; 1 8 (1kg = 380 palillos) [16.32 kg]; Base Sop Plancha 122x244x3mm [2.4 u]; Tecnico Electomecanico de Construccion EO D2; Tecnico obras civiles EO C2 [25%]; Peón EO E2; Maestro mayor en ejecución de obras civiles EO C1 [75%]; Soldadora; Herramienta Menor | 2804.4h | 21,518.1 | 503665 |  | 48.00 | 11.6851 | 560.88 | 70.11 | 444.3239 | 21327.55 | 111 |
| 113 | Señales al lado de la carretera 750x750 | 60d | 2025-09-30 | 2025-11-29 | 112SS | 0d | Placa Alum E=2mm [49.84 m2]; Platina Alum 11 2 x1 8 [267 mts]; Base Sop Plancha 122x244x3mm [1.78 u]; Perno de Refuerzo 025x050 - 1 4 x 1 2 con tuerca [178 u]; Remaches [1602 u]; Pintura Primer Gris [12.46 gln]; Fondo para Señal [49.84 m2]; Papel Reflec Grado Diamante (Leyenda) [19.58 m2]; Soldadura 6011; 1 8 (1kg = 380 palillos) [12.46 kg]; Pata Tubo HG (2 X2mm) [267 mts]; Accesorios [89 glb]; Bloque de Anclaje HS F´C= 210 kg cm2 (40x40x40) [89 u]; Tecnico Electomecanico de Construccion EO D2; Tecnico obras civiles EO C2 [25%]; Peón EO E2; Maestro mayor en ejecución de obras civiles EO C1 [75%]; Soldadora; Herramienta Menor | 3486.8h | 23,390.49 | 503666 |  | 89.00 | 7.8358 | 697.38 | 87.17 | 260.1561 | 23153.89 | 112 |
| 114 | Señales al lado de la carretera 750x750 900x300 | 60d | 2025-09-30 | 2025-11-29 | 113SS | 0d | Placa Alum E=2mm [1.66 m2]; Platina Alum 11 2 x1 8 [10.8 mts]; Base Sop Plancha 122x244x3mm [0.06 u]; Perno de Refuerzo 025x050 - 1 4 x 1 2 con tuerca [8 u]; Remaches [54 u]; Pintura Primer Gris [0.42 gln]; Fondo para Señal [1.66 m2]; Papel Reflec Grado Diamante (Leyenda) [0.66 m2]; Soldadura 6011; 1 8 (1kg = 380 palillos) [0.42 kg]; Pata Tubo HG (2 X2mm) [6 mts]; Accesorios [2 glb]; Bloque de Anclaje HS F´C= 210 kg cm2 (40x40x40) [2 u]; Tecnico Electomecanico de Construccion EO D2; Tecnico obras civiles EO C2 [25%]; Peón EO E2; Maestro mayor en ejecución de obras civiles EO C1 [75%]; Soldadora; Herramienta Menor | 110h | 736.65 | 503667 |  | 2.00 | 11.0001 | 22.00 | 2.75 | 364.5884 | 729.18 | 113 |
| 115 | SEÑALES AL LADO DE LA CARRETERA 1298x420 | 60d | 2025-09-30 | 2025-11-29 | 114SS | 0d | Placa Alum E=2mm [6.54 m2]; Platina Alum 11 2 x1 8 [8.4 mts]; Papel Reflec Grado Diamante (Leyenda) [6.54 m2]; Soldadura 6011; 1 8 (1kg = 380 palillos) [0.34 kg]; Tubo Cuadrado HG (50 x 50 x 2 mm) [72 mts]; Perno Cabeza de coco 1 4 x 3 [48 u]; Hormigon Simple f'c= 180kg cm2 [1.54 m3]; Peón EO E2 [300%]; Maestro mayor en ejecución de obras civiles EO C1; Soldador en construcción EO C3 [10%]; Soldadora; Herramienta Menor | 67.34h | 1,660.16 | 503668 |  | 12.00 | 0.9199 | 11.04 | 1.38 | 138.2466 | 1658.96 | 114 |
| 116 | Señales al lado de la carretera 1200x900 | 60d | 2025-09-30 | 2025-11-29 | 115SS | 0d | Placa Alum E=2mm [9.96 m2]; Platina Alum 11 2 x1 8 [50.4 mts]; Base Sop Plancha 122x244x3mm [0.48 u]; Perno de Refuerzo 025x050 - 1 4 x 1 2 con tuerca [24 u]; Remaches [420 u]; Pintura Primer Gris [3.24 gln]; Fondo para Señal [12.96 m2]; Papel Reflec Grado Diamante (Leyenda) [5.16 m2]; Soldadura 6011; 1 8 (1kg = 380 palillos) [3.24 kg]; Pata Tubo HG (2 X2mm) [72 mts]; Accesorios [12 glb]; Bloque de Anclaje HS F´C= 210 kg cm2 (40x40x40) [24 u]; Tecnico Electomecanico de Construccion EO D2; Tecnico obras civiles EO C2 [25%]; Peón EO E2; Maestro mayor en ejecución de obras civiles EO C1 [75%]; Soldadora; Herramienta Menor | 768.4h | 5,335.6 | 503669 |  | 12.00 | 12.8044 | 153.65 | 19.21 | 440.2444 | 5282.93 | 115 |
| 117 | Señales al lado de la carretera 1200x600 | 60d | 2025-09-30 | 2025-11-29 | 116SS | 0d | Placa Alum E=2mm [2.88 m2]; Platina Alum 11 2 x1 8 [12 mts]; Base Sop Plancha 122x244x3mm [0.12 u]; Perno de Refuerzo 025x050 - 1 4 x 1 2 con tuerca [8 u]; Remaches [92 u]; Pintura Primer Gris [0.72 gln]; Fondo para Señal [2.88 m2]; Papel Reflec Grado Diamante (Leyenda) [1.16 m2]; Soldadura 6011; 1 8 (1kg = 380 palillos) [0.72 kg]; Pata Tubo HG (2 X2mm) [24 mts]; Accesorios [4 glb]; Bloque de Anclaje HS F´C= 210 kg cm2 (40x40x40) [8 u]; Tecnico Electomecanico de Construccion EO D2; Tecnico obras civiles EO C2 [25%]; Peón EO E2; Maestro mayor en ejecución de obras civiles EO C1 [75%]; Soldadora; Herramienta Menor | 154h | 1,248.89 | 503670 |  | 4.00 | 7.6921 | 30.77 | 3.85 | 309.4775 | 1237.91 | 116 |
| 118 | Señales al lado de la carretera 600x600 | 60d | 2025-09-30 | 2025-11-29 | 117SS | 0d | Placa Alum E=2mm [18 m2]; Platina Alum 11 2 x1 8 [120 mts]; Base Sop Plancha 122x244x3mm [0.5 u]; Perno de Refuerzo 025x050 - 1 4 x 1 2 con tuerca [100 u]; Remaches [600 u]; Pintura Primer Gris [4.5 gln]; Fondo para Señal [18 m2]; Papel Reflec Grado Diamante (Leyenda) [7 m2]; Soldadura 6011; 1 8 (1kg = 380 palillos) [4.5 kg]; Pata Tubo HG (2 X2mm) [150 mts]; Accesorios [50 glb]; Bloque de Anclaje HS F´C= 210 kg cm2 (40x40x40) [50 u]; Tecnico Electomecanico de Construccion EO D2; Tecnico obras civiles EO C2 [25%]; Peón EO E2; Maestro mayor en ejecución de obras civiles EO C1 [75%]; Soldadora; Herramienta Menor | 1792h | 11,121.2 | 503671 |  | 50.00 | 7.1684 | 358.42 | 44.80 | 219.9941 | 10999.7 | 117 |
| 119 | Señales al lado de la carretera 750x600 | 60d | 2025-09-30 | 2025-11-29 | 118SS | 0d | Placa Alum E=2mm [1.8 m2]; Platina Alum 11 2 x1 8 [10.8 mts]; Base Sop Plancha 122x244x3mm [0.08 u]; Perno de Refuerzo 025x050 - 1 4 x 1 2 con tuerca [8 u]; Remaches [56 u]; Pintura Primer Gris [0.44 gln]; Fondo para Señal [1.8 m2]; Papel Reflec Grado Diamante (Leyenda) [0.72 m2]; Soldadura 6011; 1 8 (1kg = 380 palillos) [0.44 kg]; Pata Tubo HG (2 X2mm) [12 mts]; Accesorios [4 glb]; Bloque de Anclaje HS F´C= 210 kg cm2 (40x40x40) [4 u]; Tecnico Electomecanico de Construccion EO D2; Tecnico obras civiles EO C2 [25%]; Peón EO E2; Maestro mayor en ejecución de obras civiles EO C1 [75%]; Soldadora; Herramienta Menor | 146.8h | 955.31 | 503672 |  | 4.00 | 7.3326 | 29.33 | 3.67 | 236.2128 | 944.85 | 118 |
| 120 | Señales al lado de la carretera 450x600450x600 | 60d | 2025-09-30 | 2025-11-29 | 119SS | 0d | Placa Alum E=2mm [4.86 m2]; Platina Alum 11 2 x1 8 [37.8 mts]; Base Sop Plancha 122x244x3mm [0.18 u]; Perno de Refuerzo 025x050 - 1 4 x 1 2 con tuerca [18 u]; Remaches [153 u]; Pintura Primer Gris [1.26 gln]; Fondo para Señal [4.86 m2]; Papel Reflec Grado Diamante (Leyenda) [1.98 m2]; Soldadura 6011; 1 8 (1kg = 380 palillos) [1.26 kg]; Pata Tubo HG (2 X2mm) [27 mts]; Accesorios [9 glb]; Bloque de Anclaje HS F´C= 210 kg cm2 (40x40x40) [9 u]; Tecnico Electomecanico de Construccion EO D2; Tecnico obras civiles EO C2 [25%]; Peón EO E2; Maestro mayor en ejecución de obras civiles EO C1 [75%]; Soldadora; Herramienta Menor | 330h | 2,274.06 | 503673 |  | 9.00 | 7.3326 | 65.99 | 8.25 | 250.169 | 2251.52 | 119 |
| 121 | GUARDA CAMINO TIPO VIGA METALICA doble | 60d | 2025-09-30 | 2025-11-29 | 120SS | 0d | Perfil tipo W 12 1 2 pies (381) m [178.59 u]; Terminal de guardavías (e 25mm) [48.08 u]; Poste de HG ( h=180) Guardacamino [99.6 u]; Pernos de 5 8 x11 4 [1648.56 u]; Pintura Primer Gris [3.43 gln]; Pintura reflectiva (sin perlas) [13.74 gal]; Cemento tipo GU [4464.85 kg]; Piedra No 4 [10.3 m3]; Arena [6.87 m3]; Peón EO E2 [400%]; Maestro mayor en ejecución de obras civiles EO C1; Albañil EO D2 [300%]; Herramienta Menor | 409.68h | 30,616.58 | 503674 |  | 343.45 | 0.1325 | 45.50 | 5.69 | 89.239 | 30649.13 | 120 |
| 122 | SUMINISTRO E INSTALACION DE TUBO METALICO CUADRADO DE 2" | 30d | 2025-06-02 | 2025-07-01 | 1SS | 0d | Perno de Refuerzo 025x050 - 1 4 x 1 2 con tuerca [92 u]; Bloque de Anclaje HS F´C= 210 kg cm2 (40x40x40) [30.66 u]; Anticorrosivo Cromato 5 (CO) [0.92 Gln]; Tubo Cuadrado 2 x2mmx6m (293Kg) [15.64 u]; Pintura Esmalte [0.92 gln]; Peón EO E2 [200%]; Maestro mayor en ejecución de obras civiles EO C1 [20%]; Herramienta Menor | 82.94h | 1,799.99 | 503675 |  | 92.00 | 0.2814 | 25.89 | 3.24 | 19.4125 | 1785.95 | 121 |
| 123 | CINTA PLASTICA DE PELIGRO 1 LINEA | 30d | 2025-06-02 | 2025-07-01 | 122SS | 0d | Cinta peligro [3057 mts] |  | 351.56 | 503676 |  | 3,057.00 | 0.0000 | 0.00 | 0.00 | 0.115 | 351.56 | 122 |
| 124 | BARRICADA DE MADERA 0,6X1.1M C/2TABLONES C/ CINTA REFLECTIVA | 30d | 2025-06-02 | 2025-07-01 | 123SS | 0d | Cuarton Semiduro Encofrado [9 u]; Tira Semidura Encofrado 1 x 4m [10.8 u]; Tabla semidura (encofrado de 1 x 4m) [22.5 u]; Platina 1 1 2 x 1 8 (3mm); 090 kg m; 6m [24.3 mts]; Perno galv de 5 8 x 4 (incluye 2 anillos) [108 u]; Pintura Reflectiva (con perlas) [8.1 gln]; Peón EO E2; Maestro mayor en ejecución de obras civiles EO C1; Carpintero EO D2; Herramienta Menor | 108.16h | 1,423.24 | 503677 |  | 9.00 | 3.0011 | 27.01 | 3.38 | 157.0788 | 1413.71 | 123 |
| 125 | BARRICADA DE MADERA 1.20 X 1.50M C/3 TABL.C/CINTA REFLECTIVA | 30d | 2025-06-02 | 2025-07-01 | 124SS | 0d | Cuarton Semiduro Encofrado [10.8 u]; Tira Semidura Encofrado 1 x 4m [13.5 u]; Tabla semidura (encofrado de 1 x 4m) [27 u]; Platina 1 1 2 x 1 8 (3mm); 090 kg m; 6m [24.3 mts]; Perno galv de 5 8 x 4 (incluye 2 anillos) [108 u]; Pintura Reflectiva (con perlas) [8.64 gln]; Peón EO E2; Maestro mayor en ejecución de obras civiles EO C1; Carpintero EO D2; Herramienta Menor | 144h | 1,622.06 | 503678 |  | 9.00 | 3.9999 | 36.00 | 4.50 | 178.8795 | 1609.92 | 124 |
| 126 | BARRICADA DE MADERA 2.40 X 1.50M C/3 TABL.C/CINTA REFLECTIVA | 30d | 2025-06-02 | 2025-07-01 | 125SS | 0d | Cuarton Semiduro Encofrado [18 u]; Tira Semidura Encofrado 1 x 4m [18 u]; Tabla semidura (encofrado de 1 x 4m) [27 u]; Platina 1 1 2 x 1 8 (3mm); 090 kg m; 6m [24.3 mts]; Perno galv de 5 8 x 4 (incluye 2 anillos) [108 u]; Pintura Reflectiva (con perlas) [13.5 gln]; Peón EO E2; Maestro mayor en ejecución de obras civiles EO C1; Carpintero EO D2; Herramienta Menor | 144h | 1,785.66 | 503679 |  | 9.00 | 4.0003 | 36.00 | 4.50 | 197.0631 | 1773.57 | 125 |
| 127 | TANQUE PROTECTOR VIAL DE POLIETILENO H=1,02M D=0,62M INC. BASE | 30d | 2025-06-02 | 2025-07-01 | 126SS | 0d | Tanque protector Vial-Polietileno H=102M D=062M INC BASE [18 u]; Peón EO E2 | 18h | 1,718.1 | 503680 |  | 18.00 | 1.0000 | 18.00 | 2.25 | 95.45 | 1718.1 | 126 |
| 128 | PARANTE VIAL DE POLIETILENO DE H=1,41M; D=0,74M INC.BASE | 30d | 2025-06-02 | 2025-07-01 | 127SS | 0d | Parante Vial de Polietileno enroscable de H=141m D=074m (inc base) [46 u]; Peón EO E2 | 46h | 2,234.49 | 503681 |  | 46.00 | 0.9998 | 45.99 | 5.75 | 48.5751 | 2234.45 | 127 |
| 129 | CONOS REFLECTIVOS H=90 CM. | 30d | 2025-06-02 | 2025-07-01 | 128SS | 0d | Cono c cinta reflectiva (h=90cm) [40 u] |  | 1,247.52 | 503682 |  | 40.00 | 0.0000 | 0.00 | 0.00 | 31.188 | 1247.52 | 128 |
| 130 | DISPOSITIVO SEÑAL LUMINOSA DE PREVENCION H=0,3,A=0,2M CON BATERIA DE 6 VOLTIOS | 30d | 2025-06-02 | 2025-07-01 | 129SS | 0d | Señal Luminosa H=03 M A=02 M Inc Bateria 6V [9 u]; Electricista EO D2 | 8.96h | 484.62 | 503683 |  | 9.00 | 0.9994 | 8.99 | 1.12 | 53.863 | 484.77 | 129 |
| 131 | CONSTRUCCION E INSTALACION DE LETRERO METALICO REFLECTIVO SEÑALIZACION | 30d | 2025-06-02 | 2025-07-01 | 130SS | 0d | Perno de Refuerzo 025x050 - 1 4 x 1 2 con tuerca [18 u]; Placa Alum E=2mm [6.12 m2]; Anticorrosivo Cromato 5 (CO) [0.3 Gln]; Pintura Esmalte [0.3 gln]; Papel Reflec Grado Diamante (Leyenda) [9 m2]; Peón EO E2; Maestro mayor en ejecución de obras civiles EO C1 [20%]; Tecnico Electomecanico de Construccion EO D2; Herramienta Menor; Cortadora - Dobladora; Soldadora [50%] | 38.73h | 1,311.27 | 503684 | m2 | 6.00 | 1.3734 | 8.24 | 1.03 | 217.8218 | 1306.93 | 130 |
| 132 | CONOS REFLECTIVOS H=70 CM | 60d | 2025-06-02 | 2025-07-31 | 131SS | 0d | Cono c cinta reflectiva (h=70cm) [92 u] |  | 1,668.47 | 503685 |  | 92.00 | 0.0000 | 0.00 | 0.00 | 18.1355 | 1668.47 | 131 |
| 133 | MALLA PLASTICA DE SEGURIDAD COLOR | 60d | 2025-06-02 | 2025-07-31 | 132SS | 0d | Malla Plastica de Seguridad (Color) [3672 m2]; Tirraje Plastico [7200 u]; Peón EO E2 | 904.96h | 18,718.3 | 503686 | m2 | 3,600.00 | 0.2514 | 904.99 | 113.12 | 5.1996 | 18718.56 | 132 |
| 134 | Agua para control de polvo | 120d | 2025-06-02 | 2025-09-30 | 133SS | 0d | Agua [40825.4 m3]; Chofer: De Tanqueros (Estr. Oc. C1); Peón EO E2; Tanquero 14 TON | 805.44h | 73,493.79 | 503687 | m3 | 40,825.39 | 0.0066 | 268.50 | 33.56 | 1.8014 | 73542.86 | 133 |
| 135 | BATERIA SANITARIA PORTATIL unidad x mes | 120d | 2025-06-02 | 2025-09-30 | 134SS | 0d | Cabina Sanitaria Portatil [30 mensual] |  | 7,590 | 503688 |  | 30.00 | 0.0000 | 0.00 | 0.00 | 253 | 7590 | 134 |
| 136 | SEÑALES PREVENTIVAS TEMPORALES | 180d | 2025-06-02 | 2025-11-29 | 135SS | 0d | Base Sop Plancha 122x244x3mm [0.18 u]; Remaches [360 u]; Pintura Primer Gris [2.16 gln]; Soldadura 6011; 1 8 (1kg = 380 palillos) [1.8 kg]; Pintura Reflectiva (con perlas) [2.16 gln]; Tubo HG ( 2 x2 mm ) [10.44 u]; Lamina Galvanizada 1 16 [12.96 m2]; Platina Ref HG 3 4 x1 8¨ [102.6 mts]; Perno de Refuerzo [72 u]; Bloque de Anclaje HS f'c=210 kg cm2 (25x25x60) [18 u]; Peón EO E2; Maestro mayor en ejecución de obras civiles EO C1; Albañil EO D2 [200%]; Herramienta Menor | 450h | 3,107.31 | 503689 |  | 18.00 | 5.0002 | 90.00 | 11.25 | 172.0173 | 3096.31 | 135 |
| 137 | TANQUE DE 55 GALONES PARA BASURA | 30d | 2025-06-02 | 2025-07-01 | 136SS | 150d | Tanque metalico c tapa 55gl [9 u] |  | 165.6 | 503690 |  | 9.00 | 0.0000 | 0.00 | 0.00 | 18.4 | 165.6 | 136 |
| 138 | ESCOMBRERAS DISPOSICIÓN FINAL Y TRATAMIENTO PAISAJISTICO DE ZONAS DE DEPOSITO | 90d | 2025-06-02 | 2025-11-24 |  | 6.62d | Op. Tractor EO C1; Op. Rodillo autopropulsado EO C2; Chofer: De Tanqueros (Estr. Oc. C1); Engrasador EO D2; Op. Motoniveladora EO C1; Motoniveladora 135 HP; Tractor de oruga 175 HP; Rodillo Vibratorio Liso 142HP; Tanquero 8TN | 87.12h | 2,435.94 | 503691 | m3 | 5,901.00 | 0.0016 | 9.65 | 1.21 | 0.4039 | 2383.41 | 137 |
| 139 | Reunion informativa con la comunidad | 60d | 2025-06-02 | 2025-07-31 |  | 0d | Material Didactico [6 glb]; Chofer EO C1; Camioneta | 96h | 2,714.66 | 503692 |  | 6.00 | 7.9998 | 48.00 | 6.00 | 452.4414 | 2714.65 | 138 |
| 140 | MONITOREO DE RUIDO | 90d | 2025-06-02 | 2025-11-26 | 139SS | 0d | Toma de muestras con sonometro (muestreo por dia) [6 u] |  | 279.73 | 503693 |  | 6.00 | 0.0000 | 0.00 | 0.00 | 46.621 | 279.73 | 139 |

| ID | Task | Type | Duration | Start | Finish | Predecessors | Total slack | Resources | Cost | Text1 | Text3 | Text4 | Text5 | Text6 | Text7 | Text8 | Text9 |
| --- | --- | --- | --- | --- | --- | --- | --- | --- | --- | --- | --- | --- | --- | --- | --- | --- | --- |
| 141 | MONITOREO DE CALIDAD DE AIRE AMBIENTE |  | 180d | 2025-06-02 | 2025-11-29 | 140SS | 0d | Calidad de Aire Ambiente - Monitoreo de Monóxido de Carbono CO (8horas); Dióxido de Nitrogeno NO2 (1 hora); Dióxido de Azufre SO2 (24 horas); y Ozono O3 (8 horas) [6 u] | 7,866 | 503694 | 6.00 | 0.0000 | 0.00 | 0.00 | 1311 | 7866 | 140 |
| 142 | Monitoreo de Calidad de aire material particulado PM2.5 |  | 180d | 2025-06-02 | 2025-11-29 | 141SS | 0d | Material Particulado PM25 [6 u] | 1,242 | 503695 | 6.00 | 0.0000 | 0.00 | 0.00 | 207 | 1242 | 141 |
| 143 | Monitoreo de Calidad de aire material particulado PM10 |  | 180d | 2025-06-02 | 2025-11-29 | 142SS | 0d | Material Particulado PM10 [6 u] | 1,242 | 503696 | 6.00 | 0.0000 | 0.00 | 0.00 | 207 | 1242 | 142 |
| 144 | ANALISIS QUIMICO DE CALIDAD DE AGUA |  | 90d | 2025-06-02 | 2025-11-29 | 143SS | 0.12d | Monitoreo de calidad de agua [6 u] | 3,829.5 | 503697 | 6.00 | 0.0000 | 0.00 | 0.00 | 638.25 | 3829.5 | 143 |
| 145 | Fin | milestone | 0d | 2025-11-29 | 2025-11-29 | 110 | 0d |  |  |  |  |  |  |  |  |  |  |
